# 3GPP_Release-2000

Schedule from MS Project, 2000-01-03 to 2009-06-04, A marks actual dates.

## Calendars

- Standard: Mon-Fri 08:00-12:00, 13:00-17:00; Sat-Sun off.

## Resources

| Resource |
| --- |
| NP |
| N1 |
| N2 |
| N3 |
| N4 |
| N5 |
| TP |
| T1 |
| T2 |
| T3 |
| RP |
| R1 |
| R2 |
| R3 |
| R4 |
| SP |
| S1 |
| S2 |
| S3 |
| S4 |
| S5 |
| PCG |
| GP |
| No |
| CN4 |
| ? |
| WG G2 |
| G2 |
| G1 |
| G4 |
| G3 |
| All |
| Generic |
| MLST |
| G5 |
| S3; G2 |
| WG T2 |
| GP;G1 |
| G4;G5 |
| OMA |
| GP-G2 |
| Yes |
| GP; |
| N4; |
| GP; N1 |
| CT5 |
| C5 |
| C1 |
| C4 |
| C3 |
| C6 |
| G1; |
| 4 |
| ct |
| c;s;r |
| CT;RAN;SA |
| G2, |
| G1; G3 |
| CT6 |
| CT1 |
| CT1, CT3, CT4 |
| C1, C3, C4 |
| CP |
| R5 |
| C |
| Rel-8 |
| GP, G2 |

## Schedule

| ID | WBS | Task | Duration | Start | Finish | Complete | Remaining | Baseline start | Baseline finish | Baseline duration | Total slack | Constraint | Resources | Work | Actual work | Text9 | Text6 | Text1 | Text8 | Text5 |
| --- | --- | --- | --- | --- | --- | --- | --- | --- | --- | --- | --- | --- | --- | --- | --- | --- | --- | --- | --- | --- |
| 1 | 1 | VERSION 2008 March 7th after CT review | 1d | 2007-11-21 | 2007-11-21 |  |  | 2007-11-21 | 2007-11-21 | 1d | 401d | start no earlier than 2007-11-21 |  |  |  | 2044 |  |  |  |  |
| 2 | 2 | "CTRL + a" to display all the 3GPP fields | 1d | 2007-11-21 | 2007-11-21 |  |  | 2007-11-21 | 2007-11-21 | 1d | 401d | start no earlier than 2007-11-21 |  |  |  | 1462 |  |  |  |  |
| 3 | 3 | Content of Rel-8 (frozen) and Rel-9 | 1d | 2007-11-21 | 2007-11-21 |  |  | 2007-11-21 | 2007-11-21 | 1d | 401d | start no earlier than 2007-11-21 |  |  |  | 2058 |  |  |  |  |
| 4 | 4 | Gantt: dark blue=done; light blue=to be done; grey: previous values; black=summary | 1d? | 2000-01-03 | 2000-01-03 |  |  | 2000-01-03 | 2000-01-03 | 1d? | 2458d |  |  |  |  |  |  |  |  |  |
| 6 | 5 | Release 8 Features | 1d? | 2004-06-28 | 2004-06-28 |  |  | 2004-06-28 | 2004-06-28 | 1d? | 1288d | start no earlier than 2004-06-28 | CT;RAN;SA | 8h |  |  | Rel-8 |  |  |  |
| 7 | 6 | **3G Long Term Evolution - Evolved Packet System RAN part** | 644d? | 2006-09-25 A | 2009-03-12 | 26% | 474.1d? | 2006-09-25 | 2009-03-12 | 644d? | 60d |  | RP | 40424h | 8178.8h |  | Rel-8 | LTE | MCC_RAN |  |
| 8 | 6.1 | LTE – Physical Layer | 255d? | 2006-09-25 A | 2007-09-14 | 95% | 12.75d? | 2006-09-25 | 2007-09-14 | 255d? | 449d | finish no earlier than 2007-09-14 | R1 | 2040h | 1938h |  | Rel-8 | LTE-Phys | MCC_RAN |  |
| 9 | 6.2 | LTE – Radio Interface Layer 2 and 3 Protocol Aspect | 320d? | 2006-09-25 A | 2007-12-14 | 80% | 64d? | 2006-09-25 | 2007-12-14 | 320d? | 384d | finish no earlier than 2007-12-14 | R2 | 2560h | 2048h |  | Rel-8 | LTE-L23 | MCC_RAN |  |
| 10 | 6.3 | LTE – eUTRAN Interfaces | 320d? | 2006-09-25 A | 2007-12-14 | 80% | 64d? | 2006-09-25 | 2007-12-14 | 320d? | 384d | finish no earlier than 2007-12-14 | R3 | 2560h | 2048h |  | Rel-8 | LTE-interfaces | MCC_RAN |  |
| 11 | 6.4 | LTE – RF Radio Transmission/Reception, System Performance Requirements and Conformance Testing | 385d? | 2006-09-25 A | 2008-03-14 | 30% | 269.5d? | 2006-09-25 | 2008-03-14 | 385d? | 319d | finish no earlier than 2008-03-14 | R4 | 3080h | 924h |  | Rel-8 | LTE-RF | MCC_RAN |  |
| 12 | 6.5 | LTE FDD repeaters | 261d? | 2007-09-14 A | 2008-09-12 | 15% | 221.85d? | 2007-09-14 | 2008-09-12 | 261d? | 189d | finish no earlier than 2008-09-12 | R4 | 2088h | 313.2h |  | Rel-8 | LTE-Repeaters | MCC_RAN |  |
| 13 | 6.6 | **LTE – Terminal Conformance Test Specifications** | 401d? | 2007-06-01 A | 2008-12-12 | 5% | 380.95d? | 2007-06-01 | 2008-09-12 | 336d? | 124d |  | R5 | 7672h | 294.8h |  | Rel-8 | LTE-UEConTest | MCC_RAN | catherine.salinoc@nectech.fr |
| 14 | 6.6.1 | 3G Long Term Evolution – Terminal Protocol Conformance Test Specifications | 401d? | 2007-06-01 A | 2008-12-12 | 5% | 380.95d? | 2007-06-01 | 2008-09-12 | 336d? | 124d | finish no earlier than 2008-12-12 | R5 | 3208h | 160.4h |  | Rel-8 | LTE-UEConTest_SIG | Stoyan Baev | catherine.salinoc@nectech.fr, Jacob.John@motorola.com |
| 15 | 6.6.2 | 3G Long Term Evolution – Terminal Radio Transmission and Reception Conformance Test Specifications | 336d? | 2007-06-01 A | 2008-09-12 | 5% | 319.2d? | 2007-06-01 | 2008-09-12 | 336d? | 189d | finish no earlier than 2008-09-12 | R5 | 2688h | 134.4h |  | Rel-8 | LTE-UEConTest_RF | Stoyan Baev | andrea_leonardi@agilent.com |
| 16 | 6.7 | E-UTRAN Network Resource Model (NRM) Integration Reference Point (IRP) | 309d? | 2008-01-07 A | 2009-03-12 | 10% | 278.1d? | 2008-01-07 | 2009-03-12 | 309d? | 60d | finish no earlier than 2009-03-12 | S5 | 2472h | 247.2h |  | Rel-8 | E-UTRAN-OAM | Adrian |  |
| 17 | 6.8 | **E-UTRAN Data Definitions** | 275d? | 2008-02-22 | 2009-03-12 |  |  | 2008-01-07 | 2009-03-12 | 309d? | 60d |  | S5 | 6080h |  |  | Rel-8 | E-UTRAN-OAM | Adrian |  |
| 18 | 6.8.1 | Performance measurements for E-UTRAN | 210d? | 2008-02-22 | 2008-12-11 |  |  | 2007-06-07 | 2008-12-11 | 396d? | 125d | start no earlier than 2008-02-22 | S5 | 1680h |  |  | Rel-8 |  |  |  |
| 19 | 6.8.2 | Key Performance Indicators (KPIs) for E-UTRAN | 275d? | 2008-02-22 | 2009-03-12 |  |  | 2007-06-07 | 2008-12-11 | 396d? | 60d | finish no earlier than 2009-03-12 | S5 | 2200h |  |  | Rel-8 |  |  |  |
| 20 | 6.9 | **Management of Self-Organizing Networks (SON)** | 210d? | 2008-02-22 | 2008-12-11 |  |  | 2008-01-07 | 2009-03-12 | 309d? | 125d |  | S5 | 6720h |  |  | Rel-8 | E-UTRAN-OAM | Adrian |  |
| 21 | 6.9.1 | Self-Establishment of eNBs | 210d? | 2008-02-22 | 2008-12-11 |  |  | 2007-06-07 | 2008-12-11 | 396d? | 125d | start no earlier than 2008-02-22 | S5 | 1680h |  |  | Rel-8 |  |  |  |
| 22 | 6.9.2 | SON Automatic Neighbour Relations (ANR) List Management | 210d? | 2008-02-22 | 2008-12-11 |  |  | 2007-06-07 | 2008-12-11 | 396d? | 125d | finish no earlier than 2008-12-11 | S5 | 1680h |  |  | Rel-8 |  |  |  |
| 23 | 6.9.3 | SON Self-Optimization & Self-Healing handling | 210d? | 2008-02-22 | 2008-12-11 |  |  | 2007-06-07 | 2008-12-11 | 396d? | 125d | finish no earlier than 2008-12-11 | S5 | 1680h |  |  | Rel-8 |  |  |  |
| 24 | 7 | **3GPP System Architecture Evolution Specification - Evolved Packet System (non RAN aspects)** | 762d? | 2006-04-12 A | 2009-03-12 | 28% | 552.43d? | 2006-04-12 | 2009-03-12 | 762d? | 60d |  | S2; C1; C3; C4; S1 | 279951h | 57619h |  | Rel-8 | SAES | Maurice | osok.song@samsung.com |
| 25 | 7.1 | CT1 aspects of SAE (TR 24.801) | 425d? | 2007-01-04 A | 2008-09-19 | 30% | 297.5d? | 2007-02-05 | 2008-03-14 | 290d? | 184d | finish no earlier than 2008-09-19 | C1 | 3400h | 1020h |  | Rel-8 | SAES_C1 |  |  |
| 26 | 7.2 | CT3 aspects of SAE (TR 29.804) | 425d? | 2007-02-05 A | 2008-09-19 | 15% | 361.25d? | 2007-02-05 | 2008-03-14 | 290d? | 184d | finish no earlier than 2008-09-19 | C3 | 3400h | 510h |  | Rel-8 | SAES_C3 |  |  |
| 27 | 7.3 | CT4 aspects of SAE (TR 29.803) | 425d? | 2007-01-04 A | 2008-09-19 | 30% | 297.5d? | 2007-02-05 | 2008-03-14 | 290d? | 184d | finish no earlier than 2008-09-19 | C4 | 3400h | 1020h |  | Rel-8 | SAES_C4 |  |  |
| 28 | 7.4 | CT6 aspects of SAE | 276.25d? | 2007-02-05 | 2008-09-19 |  |  | 2007-02-05 | 2008-03-14 | 290d? | 184d | start no earlier than 2007-02-05 | C6 | 2210h |  |  | Rel-8 | SAES_C6 |  |  |
| 29 | 7.5 | Requirements for evolution of the 3GPP system architecture | 387d? | 2006-06-08 A | 2007-11-30 A | 100% |  | 2006-06-08 | 2007-11-30 | 387d? |  | finish no earlier than 2007-11-30 | S1 | 3096h | 3096h |  | Rel-8 | AIPN-SAE | Alain | michael.kurz@t-mobile.at |

Notes:
- 7: Text4: Takehiro Nakamura (NTT DoCoMo)
- 8: Text3: 36.2xy / Text4: Sadayuki Abeta, NTT DoCoMo
- 9: Text3: 36.3xy / Text4: Benoist Sebire, Nokia
- 10: Text3: 36.4xy / Text4: Mattias Wahlqvist, Ericsson
- 11: Text3: 36.1xy / Text4: Frank Lamprecht, Siemens
- 12: Text3: TS 36.x, TS 25.113 / Text4: Alf Ahlström, Powerwave Technologies. Ralf Michanikl, Andrew Wireless Corporation
- 13: BB place holder for a number of RAN5 Tasks / Text4: Catherine Salinoc, NEC
- 14: Dependent on RAN as well as on CT/SA WIs / Text3: TS 36.508, 36.523-1, 36.523-2, 36.523-3 / Text4: Catherine Salinoc (NEC), Jacob John (Motorola)
- 15: Text3: TS 36.508, 36.521-1, 36.521-2 / Text4: Andrea Leonardi (Agilent)
- 16: 12/07 SA#38 WID Approval / Text3: new 32.761/2/3/5 / Text4: Ericsson
- 18: SA#39 WID Approval / Text3: 32.4yz / Text4: Motorola, Huawei
- 19: SA#39 WID Approval / Text3: 32.4bc / Text4: Ericsson
- 20: SA#39 WID Approval / Text3: TS 32.xy1 SON OAM Requirements / Text4: Vodafone
- 21: SA#39 WID Approval / Text3: new 32.xyz, 32.751/2/3/5, 32.761/2/3/5 / Text4: NSN
- 22: SA#39 WID Approval / Text3: 32.xy1 SON ANR Management Requirements, 32.761/2/3/5 / Text4: Ericsson
- 23: SA#39 WID Approval / Text3: TS 32.xyz SON Self-Optimization & Self-Healing OAM Requirements, 32.751/2/3/5, 32.761/2/3/5 / Text4: Huawei
- 24: S2#52: Specification phase created. New WID approved SA#32 / Text3: 23.228, 23.279 / Text4: Osok Song (Samsung)
- 29: Text3: 22.278 / Text4: Michael Kurz (T-Mobile International)

| ID | WBS | Task | Duration | Start | Finish | Complete | Remaining | Baseline start | Baseline finish | Baseline duration | Total slack | Constraint | Resources | Work | Actual work | Text1 | Text6 | Text4 | Text5 | Text8 | Text3 |
| --- | --- | --- | --- | --- | --- | --- | --- | --- | --- | --- | --- | --- | --- | --- | --- | --- | --- | --- | --- | --- | --- |
| 30 | 7.6 | **High level and common (for all accesses) functions** | 514d? | 2007-01-02 A | 2008-12-19 | 18% | 422.8d? | 2007-01-02 | 2008-12-31 | 522d? | 119d |  | S2; C1; C3; C4 | 46916.8h | 5608.4h | EPS-ComF | Rel-8 |  |  |  |  |
| 31 | 7.6.1 | Stage 2 of High level functions | 370d? | 2007-01-02 A | 2008-06-02 | 95% | 18.5d? | 2007-01-02 | 2008-03-07 | 309d? | 263d | finish no earlier than 2008-06-02 | S2 | 2960h | 2812h | SAES-SA-HLF | Rel-8 |  |  |  |  |
| 32 | 7.6.2 | Stage 3 (CT1) for SAE impact on services, network functions and capabilities | 485d? | 2007-02-05 A | 2008-12-15 | 15% | 412.25d? | 2007-02-05 | 2008-12-15 | 485d? | 124d | finish no earlier than 2008-12-15 | C1 | 3880h | 582h | SAES-St3-CT1imp | Rel-8 | Robert Zaus (Nokia Siemens Networks) | robert.zaus@nsn.com | Andrijana |  |
| 33 | 7.6.3 | Stage 3 (CT3) for SAE impact on existing capabilities | 490d? | 2007-02-05 | 2008-12-19 |  |  | 2007-02-05 | 2008-03-14 | 290d? | 119d | finish no earlier than 2008-12-19 | C3 | 3920h |  | SAES-St3-CT3imp | Rel-8 |  |  |  |  |
| 34 | 7.6.4 | Stage 3 (CT4) of SAE impact on existing capabilities | 480d? | 2007-02-05 A | 2008-12-05 | 10% | 432d? | 2007-02-05 | 2008-05-30 | 345d? | 129d | finish no earlier than 2008-12-05 | C4 | 3840h | 384h | SAES-St3-impacts | Rel-8 |  |  |  |  |
| 35 | 7.6.5 | Stage 2/3 for Network selection procedures | 485d? | 2007-02-05 A | 2008-12-15 | 15% | 412.25d? | 2007-02-05 | 2008-12-15 | 485d? | 124d | finish no earlier than 2008-12-15 | C1 | 3880h | 582h | SAES-St3-netsel | Rel-8 | Robert Zaus (Nokia Siemens Networks) | robert.zaus@nsn.com | Andrijana |  |
| 36 | 7.6.6 | Stage 3 PCC aspects of SAE | 490d? | 2007-02-05 | 2008-12-19 |  |  | 2007-02-05 | 2008-12-31 | 498d? | 119d | finish no earlier than 2008-12-19 | C3 | 3920h |  | SAES-St3-PCC | Rel-8 |  |  | MEREDITH, John M |  |
| 37 | 7.6.7 | Stage 3 of Interworking between EPC and external PDNs (SGi) | 490d? | 2007-02-05 A | 2008-12-19 | 2% | 481.5d? | 2007-02-05 | 2008-03-14 | 290d? | 119d | finish no earlier than 2008-12-19 | C3 | 3920h | 68h | SAES-St3-intwk | Rel-8 |  |  |  |  |
| 38 | 7.6.8 | Stage 3 of SAE / LTE identities | 480d? | 2007-02-05 A | 2008-12-05 | 10% | 432d? | 2007-02-05 | 2008-05-30 | 345d? | 129d | finish no earlier than 2008-12-05 | C4 | 3840h | 384h | SAES-St3-IDs | Rel-8 |  |  |  |  |
| 39 | 7.6.9 | Unified guidelines of Diameter usage within 3GPP | 181d? | 2007-09-21 A | 2008-05-30 | 55% | 81.45d? | 2007-09-21 | 2008-05-30 | 181d? | 264d | finish no earlier than 2008-05-30 | C3 | 1448h | 796.4h | SAES-DIAM | Rel-8 | Javier Gonzalez Gallego, Huawei |  | MEREDITH, John M | 29.909 |
| 40 | 7.7 | **SAE for LTE access** | 514d? | 2007-01-02 A | 2008-12-19 | 25% | 386.11d? | 2007-01-02 | 2008-05-30 | 369d? | 119d |  | S2; C1; C3; C4 | 64616h | 12973h | SAES-SA-FP_LTE | Rel-8 |  |  |  |  |
| 41 | 7.7.1 | Stage 3 for protocol between EPCs | 480d? | 2007-02-05 A | 2008-12-05 | 10% | 432d? | 2007-02-05 | 2008-05-30 | 345d? | 129d | finish no earlier than 2008-12-05 | C4 | 3840h | 384h | SAES-St3-EPC_EPC | Rel-8 |  |  |  |  |
| 42 | 7.2.2.1 | **SAES-SA-FP_LTE with GTP variant** | 504d? | 2007-01-02 A | 2008-12-05 | 46% | 273.7d? | 2007-01-02 | 2008-05-30 | 369d? | 129d |  | S2; C4 | 14672h | 4374.4h | SAES-SA-FP_LTE-GTP | Rel-8 |  |  |  |  |
| 43 | 7.7.2.1 | Stage 2 for SAES-SA-FP_LTE with GTP variant | 370d? | 2007-01-02 A | 2008-06-02 | 92% | 29.6d? | 2007-01-02 | 2008-03-07 | 309d? | 263d | finish no earlier than 2008-06-02 | S2 | 2960h | 2723.2h | SAES-SA-FP_LTE-GTP-St2 | Rel-8 |  |  |  |  |
| 44 | 7.7.2.2 | Stage 3 for GTP v2 protocol | 480d? | 2007-02-05 A | 2008-12-05 | 10% | 432d? | 2007-02-05 | 2008-05-30 | 345d? | 129d | finish no earlier than 2008-12-05 | C4 | 3840h | 384h | SAES-St3-EPC | Rel-8 |  |  |  |  |
| 45 | 7.2.2.2 | **SAES-SA-FP_LTE with PMIP variant** | 504d? | 2007-01-02 A | 2008-12-05 | 47% | 267.12d? | 2007-01-02 | 2008-05-30 | 369d? | 129d |  | S2 | 10832h | 5091.04h | SAES-SA-FP_LTE-IETF | Rel-8 |  |  |  |  |
| 46 | 7.7.3.1 | Stage 2 for SAES-SA-FP_LTE with PMIP variant | 370d? | 2007-01-02 A | 2008-06-02 | 95% | 18.5d? | 2007-01-02 | 2008-03-07 | 309d? | 263d | finish no earlier than 2008-06-02 | S2 | 2960h | 2812h | SAES-SA-FP_LTE-IETF-St2 | Rel-8 |  |  |  |  |
| 47 | 7.7.3.2 | Stage 3 for PMIP protocol within EPC | 480d? | 2007-02-05 A | 2008-12-05 | 10% | 432d? | 2007-02-05 | 2008-05-30 | 345d? | 129d | finish no earlier than 2008-12-05 | C4 | 3840h | 384h | SAES-St3-EPC | Rel-8 |  |  |  |  |
| 48 | 7.7.4 | Stage 3 for UE NAS mobility procedures in idle and active mode | 485d? | 2007-02-05 A | 2008-12-15 | 23% | 373.45d? | 2007-02-05 | 2008-03-14 | 290d? | 124d | finish no earlier than 2008-12-15 | C1 | 3880h | 892.4h | SAES-St3-NASmob | Rel-8 | Robert Zaus (Nokia Siemens Networks) | robert.zaus@nsn.com | Andrijana | 24.301 |
| 49 | 7.7.5 | Stage 3 for Session management, bearer control and QoS aspects | 485d? | 2007-02-05 A | 2008-12-15 | 21% | 383.15d? | 2007-02-05 | 2008-03-14 | 290d? | 124d | finish no earlier than 2008-12-15 | C1 | 3880h | 814.8h | SAES-St3-BCQOS | Rel-8 | Robert Zaus (Nokia Siemens Networks) | robert.zaus@nsn.com | Andrijana | 24.301 |
| 50 | 7.7.6 | Stage 3 for security aspects for LTE Access | 485d? | 2007-02-05 A | 2008-12-15 | 10% | 436.5d? | 2007-02-05 | 2008-03-14 | 290d? | 124d | finish no earlier than 2008-12-15 | C1 | 3880h | 388h | SAES-St3-CT1sec-LTE | Rel-8 | Robert Zaus (Nokia Siemens Networks) | robert.zaus@nsn.com | Andrijana | 24.301 |
| 51 | 7.7.7 | Stage 3 for QoS mechanisms | 490d? | 2007-02-05 | 2008-12-19 |  |  | 2007-02-05 | 2008-03-14 | 290d? | 119d | finish no earlier than 2008-12-19 | C3 | 3920h |  | SAES-St3-QoS | Rel-8 |  |  |  |  |
| 52 | 7.7.8 | Stage 3 for EPC - HSS interface | 480d? | 2007-02-05 A | 2008-12-05 | 10% | 432d? | 2007-02-05 | 2008-05-30 | 345d? | 129d | finish no earlier than 2008-12-05 | C4 | 3840h | 384h | SAES-St3-EPC_HSS | Rel-8 |  |  |  |  |
| 53 | 7.8 | **SAE for Interoperation between LTE and legacy cellular PS accesses** | 485d? | 2007-02-05 A | 2008-12-15 | 22% | 377.42d? | 2007-02-05 | 2008-12-15 | 485d? | 124d |  | S2; C1; C3; C4 | 44688h | 9912h | SAES-SA-FP_3GPP | Rel-8 |  |  |  |  |
| 54 | 7.8.1 | Stage 3 for Inter-system mobility between E-UTRAN and 2G/3G | 485d? | 2007-02-05 A | 2008-12-12 | 4% | 465.6d? | 2007-02-05 | 2008-12-12 | 485d? | 124d | start no earlier than 2007-02-05 | C1 | 3880h | 155.2h | SAES-St3-intersys-2_3G | Rel-8 | Robert Zaus (Nokia Siemens Networks) | robert.zaus@nsn.com | Andrijana |  |
| 55 | 7.8.2 | Stage 2 for Interoperation between LTE and 2G/3G | 351d? | 2007-02-05 A | 2008-06-09 | 85% | 52.65d? | 2007-02-05 | 2008-03-07 | 285d? | 258d | finish no earlier than 2008-06-09 | S2 | 2808h | 2386.8h | EPSto2_3G | Rel-8 |  |  |  |  |
| 56 | 7.8.3 | GPRS for EPC (23.060, etc.) | 180d? | 2008-01-14 A | 2008-09-19 | 15% | 153d? | 2007-02-05 | 2008-03-07 | 285d? | 184d | start no earlier than 2008-01-14 | S2 | 1440h | 216h | GPRS-for-EPC | Rel-8 |  |  |  |  |
| 57 | 7.8.4 | Stage 3 of EPC - GPRS | 480d? | 2007-02-05 A | 2008-12-05 | 10% | 432d? | 2007-02-05 | 2008-05-30 | 345d? | 129d | finish no earlier than 2008-12-05 | C4 | 3840h | 384h | SAES-St3-EPC_GPRS | Rel-8 |  |  |  |  |
| 58 | 7.8.5 | Stage 3 of EPC to UTRAN | 480d? | 2007-02-05 A | 2008-12-05 | 10% | 432d? | 2007-02-05 | 2008-05-30 | 345d? | 129d | finish no earlier than 2008-12-05 | C4 | 3840h | 384h | SAES-St3-EPC_UTRAN | Rel-8 |  |  |  |  |
| 59 | 7.8.6 | Stage 3 of EPC to 3GPP2 | 480d? | 2007-02-05 A | 2008-12-05 | 10% | 432d? | 2007-02-05 | 2008-05-30 | 345d? | 129d | finish no earlier than 2008-12-05 | C4 | 3840h | 384h | SAES-St3-EPC_3GPP2 | Rel-8 |  |  |  |  |
| 60 | 7.8.7 | Stage 2 for Interoperation between LTE and CDMA2000 | 225d? | 2007-06-18 A | 2008-04-25 | 95% | 11.25d? | 2007-06-18 | 2008-03-07 | 190d? | 289d | finish no earlier than 2008-04-25 | S2 | 1800h | 1710h | EPStoC2k | Rel-8 |  |  |  |  |
| 61 | 7.8.8 | Stage 3 for Inter-system mobility between E-UTRAN and CDMA2000 | 485d? | 2007-02-05 A | 2008-12-15 | 12% | 426.8d? | 2007-02-05 | 2008-12-15 | 485d? | 124d | finish no earlier than 2008-12-15 | C1 | 3880h | 465.6h | SAES-St3-intersys-C2k | Rel-8 | Robert Zaus (Nokia Siemens Networks) | robert.zaus@nsn.com | Andrijana |  |
| 62 | 7.8.9 | Stage 3 for MME - SGSN "signalling free" protocol | 480d? | 2007-02-05 A | 2008-12-05 | 10% | 432d? | 2007-02-05 | 2008-05-30 | 345d? | 129d | finish no earlier than 2008-12-05 | C4 | 3840h | 384h | SAES-St3-MME_SGSN | Rel-8 |  |  |  |  |

Notes:
- 36: C3-46: Progress made but completion date now estimated end 2008
- 39: CP-37: WI approved. C3-46: early draft of 29.909 available.
- 41: Name changed from "Stage 3 for PMIP protocol between EPCs" to incorporate GTP part also

| ID | WBS | Task | Type | Duration | Start | Finish | Complete | Remaining | Baseline start | Baseline finish | Baseline duration | Total slack | Constraint | Resources | Work | Actual work | Text1 | Text6 | Text5 | Text8 | Text12 |
| --- | --- | --- | --- | --- | --- | --- | --- | --- | --- | --- | --- | --- | --- | --- | --- | --- | --- | --- | --- | --- | --- |
| 63 | 7.9 | **SAE for support of non-3GPP accesses** |  | 509d? | 2007-01-02 A | 2008-12-15 | 29% | 363.54d? | 2007-01-02 | 2008-12-15 | 509d? | 124d |  | S2; C1; C3; C4 | 56856h | 12235.6h | SAES-SA-FP_n3GPP | Rel-8 |  |  |  |
| 64 | 7.2.4.1 | Stage 2 for Host-based Mobility aspects |  | 334d? | 2007-01-02 A | 2008-04-11 | 95% | 16.7d? | 2007-01-02 | 2008-03-07 | 309d? | 299d | finish no earlier than 2008-04-11 | S2 | 2672h | 2538.4h | SAES-SA-FP_n3GPP-HBMob | Rel-8 |  |  |  |
| 65 | 7.2.4.2 | Stage 2 for Network-based Mobility aspects |  | 375d? | 2007-01-02 A | 2008-06-09 | 85% | 56.25d? | 2007-01-02 | 2008-03-07 | 309d? | 258d | finish no earlier than 2008-06-09 | S2 | 3000h | 2550h | SAES-SA-FP_n3GPP-NBMob | Rel-8 |  |  |  |
| 66 | 7.9.3 | Stage 2 for Optimised Dual-Radio Handover with WiMAX |  | 251d? | 2007-06-25 A | 2008-06-09 | 65% | 87.85d? | 2007-06-25 | 2008-06-13 | 255d? | 258d | finish no earlier than 2008-06-09 | S2 | 2008h | 1305.2h | SAES-SA-FP_n3GPP-OptWIMAX | Rel-8 |  |  |  |
| 67 | 7.9.4 | Stage 3 for Access to the EPC via non-3GPP access networks |  | 485d? | 2007-02-05 A | 2008-12-15 | 18% | 397.7d? | 2007-02-05 | 2008-12-15 | 485d? | 124d | finish no earlier than 2008-12-15 | C1 | 3880h | 698.4h | SAES-St3-non-3GPP | Rel-8 | robert.zaus@nsn.com | Andrijana |  |
| 68 | 7.9.5 | Stage 3 for Mobility management based on mobile IP DSMIP v6 |  | 485d? | 2007-02-05 A | 2008-12-15 | 50% | 242.5d? | 2007-02-05 | 2008-12-15 | 485d? | 124d | finish no earlier than 2008-12-15 | C1 | 3880h | 1940h | SAES-St3-CT1MIP | Rel-8 | robert.zaus@nsn.com | Andrijana |  |
| 69 | 7.9.6 | Stage 3 for Mobility management based on mobile IP v4 |  | 485d? | 2007-02-05 A | 2008-12-12 | 15% | 412.25d? |  |  |  | 124d | start no earlier than 2007-02-05 | C1 | 3880h | 582h | SAES-St3-CT1MIP | Rel-8 | robert.zaus@nsn.com | Andrijana |  |
| 70 | 7.9.7 | Stage 3 for Inter-system mobility between E-UTRAN and non 3GPP accesses |  | 485d? | 2007-02-05 A | 2008-12-12 | 4% | 465.6d? | 2007-02-05 | 2008-12-12 | 485d? | 124d | start no earlier than 2007-02-05 | C1 | 3880h | 155.2h | SAES-St3-intersys-n3GPP | Rel-8 | robert.zaus@nsn.com | Andrijana |  |
| 71 | 7.9.8 | Stage 3 security aspects for non3GPP Access |  | 485d? | 2007-02-05 A | 2008-12-15 | 15% | 412.25d? | 2007-02-05 | 2008-12-15 | 485d? | 124d | finish no earlier than 2008-12-15 | C1 | 3880h | 582h | SAES-St3-CT1sec-MIP | Rel-8 | robert.zaus@nsn.com | Andrijana |  |
| 72 | 7.9.9 | Stage 3 for interfaces within EPC |  | 318d? | 2007-09-19 A | 2008-12-05 | 10% | 286.2d? | 2007-09-19 | 2008-05-30 | 183d? | 129d | finish no earlier than 2008-12-05 | C4 | 2544h | 254.4h | EPS-int_ifSt3 | Rel-8 |  |  |  |
| 73 | 7.9.10 | Stage 3 for Interfaces EPC - non-3GPP IP access |  | 480d? | 2007-02-05 A | 2008-12-05 | 10% | 432d? | 2007-02-05 | 2008-05-30 | 345d? | 129d | finish no earlier than 2008-12-05 | C4 | 3840h | 384h | SAES-St3-EPC_n3G | Rel-8 |  |  |  |
| 74 | 7.9.11 | Stage 3 for AAA/HSS related |  | 480d? | 2007-02-05 A | 2008-12-05 | 10% | 432d? | 2007-02-05 | 2008-05-30 | 345d? | 129d | finish no earlier than 2008-12-05 | C4 | 3840h | 384h | SAES-St3-AAA_HSS | Rel-8 |  |  |  |
| 75 | 7.9.12 | Stage 3 for EPC - AAA interface |  | 480d? | 2007-02-05 A | 2008-12-05 | 10% | 432d? | 2007-02-05 | 2007-11-30 | 215d? | 129d | finish no earlier than 2008-12-05 | C4 | 3840h | 384h | SAES-St3-EPC_AAA | Rel-8 |  |  |  |
| 76 | 7.9.13 | Deleted (already covered) SAES-SA-FP_n3GPP Optimised Handover with CDMA | milestone | 0d? | 2007-06-25 A | 2007-06-25 A | 100% |  | 2007-06-25 | 2007-06-25 | 0d? |  | finish no earlier than 2007-06-25 | S2 |  |  | SAES-SA-FP_n3GPP-OptCDMA | Rel-8 |  |  |  |
| 77 | 7.10 | Functions and procedures for SAE to support LTE MBMS |  | 381d? | 2007-06-25 A | 2008-12-08 | 40% | 228.6d? | 2007-06-25 | 2008-06-13 | 255d? | 128d | finish no earlier than 2008-12-08 | S2 | 3048h | 1219.2h | SAES-SA-FP_LTEMBMS | Rel-8 |  |  |  |
| 78 | 7.11 | Single Radio Voice Call Continuity for 3GPP |  | 445d? | 2007-01-02 A | 2008-09-15 | 50% | 222.5d? | 2007-01-02 | 2008-06-13 | 379d? | 188d | finish no earlier than 2008-09-15 | S2 | 3560h | 1780h | SAES-SA-SR_VCC_3G | Rel-8 |  |  |  |
| 79 | 7.12 | Voice Call Continuity for CDMA2000 1X |  | 255d? | 2007-06-25 A | 2008-06-13 | 80% | 51d? | 2007-06-25 | 2008-06-13 | 255d? | 254d | finish no earlier than 2008-06-13 | S2 | 2040h | 1632h | SAES-SA-VCC_1X | Rel-8 |  |  |  |
| 80 | 7.13 | SAE impacts on IMS |  | 379d? | 2007-01-02 A | 2008-06-13 | 40% | 227.4d? | 2007-01-02 | 2008-06-13 | 379d? | 254d | finish no earlier than 2008-06-13 | S2 | 3032h | 1212.8h | SAES-SA-on_IMS | Rel-8 |  |  |  |
| 81 | 7.14 | EPC Network Resource Model (NRM) Integration Reference Point (IRP) |  | 309d? | 2008-01-07 A | 2009-03-12 | 10% | 278.1d? | 2008-01-07 | 2009-03-12 | 309d? | 60d | finish no earlier than 2009-03-12 | S5 | 2472h | 247.2h | EPC-OAM | Rel-8 |  | Adrian |  |
| 82 | 7.15 | **EPC Data Definitions** |  | 210d? | 2008-02-22 | 2008-12-11 |  |  | 2008-01-07 | 2009-03-12 | 309d? | 125d |  | S5 | 3360h |  | EPC-OAM | Rel-8 |  | Adrian |  |
| 83 | 7.15.1 | Performance measurements for EPC |  | 210d? | 2008-02-22 | 2008-12-11 |  |  | 2007-06-07 | 2008-12-11 | 396d? | 125d | start no earlier than 2008-02-22 | S5 | 1680h |  |  | Rel-8 |  |  |  |
| 84 | 7.16 | EPC Charging |  | 309d? | 2008-01-07 A | 2009-03-12 | 20% | 247.2d? | 2008-01-07 | 2009-03-12 | 309d? | 60d | finish no earlier than 2009-03-12 | S5 | 2472h | 494.4h | EPC-CH | Rel-8 |  | Adrian |  |
| 85 | 7.17 | Deleted (covered by 380068): Functions and procedures for SAE to support LCS | milestone | 0d? | 2008-03-03 A | 2008-03-03 A | 100% |  | 2007-08-13 | 2008-06-13 | 220d? |  | finish no earlier than 2008-03-03 | S2 |  |  | SAES-SA-FP_LCS | Rel-8 |  |  |  |
| 86 | 7.18 | Deleted (covered by 380064): SAE aspects of Emergency Calls | milestone | 0d? | 2008-03-03 A | 2008-03-03 A | 100% |  | 2007-10-08 | 2008-09-12 | 245d? |  | start no earlier than 2008-03-03 | S2 |  |  | SAES-SA-EmCall | Rel-8 |  |  |  |
| 87 | 7.19 | Deleted - CT1 aspects of SAES | milestone | 0d? | 2007-09-04 A | 2007-09-27 A | 100% |  | 2007-09-04 | 2007-09-27 | 0d? |  | start no earlier than 2007-09-04 | CP; C1 |  |  | SAES-St3 | Rel-8 |  |  |  |
| 88 | 7.20 | Deleted - CT1 aspects of SAES | milestone | 0d? | 2007-09-04 A | 2007-09-04 A | 100% |  | 2007-09-04 | 2007-09-04 | 0d? |  | start no earlier than 2007-09-04 | C1 |  |  | SAES-St3 | Rel-8 |  |  |  |
| 89 | 7.21 | Deleted - Interoperability | milestone | 0d? | 2008-03-14 A | 2008-03-14 A | 100% |  | 2008-03-14 | 2008-03-14 | 0d? |  | start no earlier than 2008-03-14 | C1 |  |  | SAES-St3-interop | Rel-8 |  |  |  |
| 90 | 7.22 | Deleted - CT3 aspects of SAES | milestone | 0d? | 2007-09-04 A | 2007-09-04 A | 100% |  | 2007-09-04 | 2007-09-04 | 0d? |  | start no earlier than 2007-09-04 | C3 |  |  | SAES-St3 | Rel-8 |  |  |  |
| 91 | 7.23 | Deleted - CT4 aspects of SAES | milestone | 0d? | 2007-09-04 A | 2007-09-04 A | 100% |  | 2007-09-04 | 2007-09-04 | 0d? |  | start no earlier than 2007-09-04 | C4 |  |  | SAES-St3 | Rel-8 |  |  |  |
| 92 | 7.24 | Deleted - UE to EPC NAS signalling (incl. MBMS and QoS aspects) | milestone | 0d? | 2008-03-14 A | 2008-03-14 A | 100% |  | 2008-03-14 | 2008-03-14 | 0d? |  | start no earlier than 2008-03-14 | C1 |  |  | SAES-St3-sig | Rel-8 |  |  |  |
| 93 | 7.25 | Deleted -User and Control plane protocols | milestone | 0d? | 2007-09-21 A | 2007-09-21 A | 100% |  | 2007-09-21 | 2007-09-21 | 0d? |  | start no earlier than 2007-09-21 | C4 |  |  | SAES-St3-prot | Rel-8 |  |  |  |
| 94 | 7.26 | Deleted - GPRS enhancements for LTE access | milestone | 0d? | 2007-09-04 A | 2007-09-04 A | 100% |  | 2007-09-04 | 2007-09-04 | 0d? |  | start no earlier than 2007-09-04 | S2 |  |  | SAES-GPRS_LTE | Rel-8 | chris.pudney@vodafone.com | Maurice |  |
| 95 | 7.27 | Deleted - Architecture enhancements for non-3GPP accesses | milestone | 0d? | 2007-09-04 A | 2007-09-04 A | 100% |  | 2007-09-04 | 2007-09-04 | 0d? |  | start no earlier than 2007-09-04 | S2 |  |  | SAES-non_3GPP | Rel-8 | Irfan.Ali@motorola.com | Maurice |  |
| 96 | 7.28 | Deleted: Stage 2 of architecture for the 3GPP System Architecture Evolution | milestone | 0d? | 2007-10-02 A | 2007-10-02 A | 100% |  | 2007-10-02 | 2007-10-02 | 0d? |  | start no earlier than 2007-10-02 | S2 |  |  | SAES-St2 | Rel-8 | chris.pudney@vodafone.com | Maurice | SP-34 |
| 97 | 7.29 | deleted - SA aspects of System Architecture Evolution |  | 384d? | 2006-04-12 A | 2007-10-02 A | 100% |  | 2006-04-12 | 2007-10-02 | 384d? |  | finish no earlier than 2007-10-02 | S2 | 3072h | 3072h | SAES-SA | Rel-8 |  |  |  |
| 98 | 8 | GERAN support for GERAN - 3G Long Term Evolution interworking |  | 576d? | 2006-09-08 A | 2008-11-21 | 45% | 316.8d? | 2006-09-08 | 2008-02-22 | 381d? | 139d | finish no earlier than 2008-11-21 | GP | 4608h | 2073.6h | GELTE | Rel-8 | sergio.parolari@nsn.com, vlora.rexhepi@nokia.com | Paolo |  |

Notes:
- 67: Text3: 24.302 / Text4: Robert Zaus (Nokia Siemens Networks)
- 68: Text3: 24.303 / Text4: Robert Zaus (Nokia Siemens Networks)
- 69: Text3: 24.304 / Text4: Robert Zaus (Nokia Siemens Networks)
- 70: Text4: Robert Zaus (Nokia Siemens Networks)
- 71: Text4: Robert Zaus (Nokia Siemens Networks)
- 78: WID Approved at SA#38 / Text4: Curt Wong (Nokia Siemens Networks)
- 81: 12/07 SA#38 WID Approval / Text3: new 32.751/2/3/5 / Text4: Huawei
- 83: SA#39 WID Approval / Text4: China Mobile
- 84: 12/07 SA#38 WID Approval / Text3: 32.240/ 296/ 251/ 252/ 298/ 299 / Text4: NSN
- 85: SA2 need RAN outputs (RAN dependencies)
- 86: Progress expected S2#60
- 91: Text3: 29.803
- 94: SP-34: GPRS enhancements for LTE access item created. / Text3: 23.401 / Text4: Chris Pudney (Vodafone)
- 95: SP-34: Architecture enhancements for non-3GPP accesses item created. / Text3: 23.402 / Text4: Irfan Ali (Motorola)
- 96: THIS LINE IS DELETED, replaced by the 2 Architecture parallel tracks. / Text3: 23.002, 23.060, 23.107, 23.203, 23.228, 23.234, 23.246, 23.271, 23.279 / Text4: Chris Pudney (Vodafone)
- 97: S2 internal target is September 2007
- 98: Text3: 24.008, 43.055, 43.129, 43.246, 44.018, 44.060, 45.002, 45.008, 45.010, 48.008,48.018, 51.010 / Text4: Vlora Rexhepi - van der Pol, NOKIA Corporation, / Sergio Parolari, Nokia Siemens Networks S.p.A.

| ID | WBS | Task | Type | Duration | Start | Finish | Complete | Remaining | Baseline start | Baseline finish | Baseline duration | Total slack | Constraint | Resources | Work | Actual work | Text1 | Text6 | Text3 | Text5 | Text8 |
| --- | --- | --- | --- | --- | --- | --- | --- | --- | --- | --- | --- | --- | --- | --- | --- | --- | --- | --- | --- | --- | --- |
| 99 | 9 | **Contact Manager for 3GPP UICC applications** |  | 577d? | 2006-06-22 A | 2008-09-05 | 65% | 199.43d? | 2006-06-22 | 2008-03-07 | 447d? | 194d |  | C6 | 12312h | 5036h | eUPHBOOK | Rel-8 |  |  |  |
| 100 | 9.1 | Requirements for Contact Manager |  | 392d? | 2006-06-22 A | 2007-12-21 A | 100% |  | 2006-06-22 | 2007-12-21 | 392d? |  | finish no earlier than 2007-12-21 | C6 | 3136h | 3136h | eUPHBOOK-St1 | Rel-8 | 21.111 |  |  |
| 101 | 9.2 | External interface for eUPHBOOK |  | 220d? | 2007-05-07 A | 2008-03-07 A | 100% |  | 2007-05-07 | 2008-03-07 | 220d? |  | finish no earlier than 2008-03-07 | C6 | 1760h | 1760h | eUPHBOOK-Spec | Rel-8 | 31.xyz |  |  |
| 102 | 9.3 | Internal interface for eUPHBOOK |  | 350d? | 2007-05-07 A | 2008-09-05 | 5% | 332.5d? | 2007-05-07 | 2008-03-07 | 220d? | 194d | finish no earlier than 2008-09-05 | C6 | 2800h | 140h | eUPHBOOK-Spec | Rel-8 | 31.xyz |  |  |
| 103 | 9.4 | Deleted - Implementation of eUPHBOOK | milestone | 0d? | 2007-06-21 A | 2007-06-21 A | 100% |  | 2007-06-21 | 2007-06-21 | 0d? |  | start no earlier than 2007-06-21 | C6 |  |  | eUPHBOOK-St23 | Rel-8 | 31.102 |  |  |
| 104 | 10 | **Enhancements for VGCS Applications** |  | 588d? | 2006-03-15 A | 2008-06-15 | 97% | 18.49d? | 2006-03-15 | 2008-03-21 | 528d? | 254d |  | S1 | 18216h | 13240h | EVA | Rel-8 | 42.068 | deola@nortel.com | Alain |
| 105 | 10.1 | SA1 aspects for EVA |  | 191d? | 2006-03-15 A | 2006-12-06 A | 100% |  | 2006-03-15 | 2006-12-06 | 191d? |  | finish no earlier than 2006-12-06 | S1 | 1528h | 1528h | EVA-s1 | Rel-8 | 42.068 | deola@nortel.com | Alain |
| 106 | 10.2 | C1 aspects for EVA |  | 531d? | 2006-06-02 A | 2008-06-15 | 90% | 53.1d? | 2006-06-02 | 2008-03-21 | 471d? | 254d | finish no earlier than 2008-06-15 | C1 | 4248h | 3823.2h | EVA | Rel-8 | 43.068, 44.068 | milanpa@nortel.com | Andrijana |
| 107 | 10.3 | C4 aspects for EVA |  | 391d? | 2006-06-02 A | 2007-11-30 A | 100% |  | 2006-06-02 | 2007-11-30 | 391d? |  | finish no earlier than 2007-06-01 | C4 | 3128h | 3128h | EVA-c4 | Rel-8 | 29.002 |  | Kimmo |
| 108 | 10.4 | GERAN2 Aspects of EVA |  | 431d? | 2006-06-30 A | 2008-02-22 A | 100% |  | 2006-06-30 | 2008-02-22 | 431d? |  | finish no earlier than 2008-02-22 | G2 | 3448h | 3448h | EVA-EVGCSA | Rel-8 | 44.018, 48.008 | frank.billenkamp@nortel.com | Gert |
| 109 | 10.5 | VGCS/VBS and GPRS Interactions |  | 145d? | 2007-09-03 A | 2008-03-21 A | 100% |  | 2007-09-03 | 2008-03-21 | 145d? |  | finish no earlier than 2008-03-21 | S1 | 1160h | 1160h | EVA-GPRS | Rel-8 | 42.068, 42.069 |  |  |
| 110 | 11 | **Multimedia Priority Service** |  | 721d? | 2006-06-08 A | 2009-03-12 | 35% | 469.93d? | 2006-06-08 | 2008-06-14 | 527d? | 60d |  | S1; C1; C3; C4 | 30132.8h | 6049.2h | PRIOR | Rel-8 | 22.153 | jgarraha@telcordia.com | Alain |
| 111 | 11.1 | Service Requirements for PRIOR |  | 387d? | 2006-06-08 A | 2007-11-30 A | 100% |  | 2006-06-08 | 2007-11-30 | 387d? |  | finish no earlier than 2007-11-30 | S1 | 3096h | 3096h | PRIOR-EMR | Rel-8 | 22.153 | jgarraha@telcordia.com | Alain |
| 112 | 11.2 | Stage 3 (CT1) for PRIOR |  | 466d? | 2006-12-01 A | 2008-09-14 | 42% | 270.28d? | 2006-12-01 | 2008-06-14 | 401d? | 189d | finish no earlier than 2008-09-14 | C1 | 3728h | 1565.76h | PRIOR-MM | Rel-8 | 24.229 | drage@Alcatel-Lucent.com | Andrijana |
| 113 | 11.3 | Stage 3 (CT3) for PRIOR |  | 256d? | 2007-09-21 | 2008-09-14 |  |  | 2007-09-21 | 2008-03-14 | 126d? | 189d | finish no earlier than 2008-09-14 | C3 | 2048h |  | PRIOR-MM | Rel-8 | 29.212, 29.213, 29.214, 29.163 |  | Seung Don |
| 114 | 11.4 | Stage 3 (CT4) for PRIOR |  | 181d? | 2007-09-21 A | 2008-05-30 | 3% | 175.57d? | 2007-09-21 | 2008-03-14 | 126d? | 264d | finish no earlier than 2008-05-30 | C4 | 1448h | 43.44h | PRIOR-MM | Rel-8 | 23.008, 29.228, 29.229 |  | Kimmo |
| 115 | 11.5 | Codec specific part of FSEV_EPS |  | 399d? | 2007-09-03 | 2009-03-12 |  |  | 2007-09-03 | 2008-03-14 | 140d? | 60d | finish no earlier than 2009-03-12 | S4 | 3192h |  | FSEV_EPS-S4 | Rel-9 |  | tim.haysom@orange-ftgroup.com, stefan.bruhn@ericson.com | Paolo |
| 116 | 12 | **System enhancements for interconnection interfaces between two IMSs** |  | 548d? | 2006-08-16 A | 2008-09-19 | 55% | 247.98d? | 2006-08-16 | 2008-05-30 | 468d? | 184d |  | S2 | 9784h | 3214.36h | IMS_NNI | Rel-8 |  |  |  |
| 117 | 12.1 | Stage 2 of IMS_NNI |  | 131d? | 2007-06-22 A | 2007-12-21 A | 100% |  | 2007-06-22 | 2007-12-21 | 131d? |  | finish no earlier than 2007-12-21 | S2 | 1048h | 1048h | IMS_NNI | Rel-8 |  |  |  |
| 118 | 12.2 | IMS inter-operator service interconnection interface |  | 341d? | 2007-06-01 A | 2008-09-19 | 55% | 153.45d? | 2007-06-01 | 2008-05-30 | 261d? | 184d | finish no earlier than 2008-09-19 | C3 | 2728h | 1500.4h | FBI2-IOPSI | Rel-8 | 29.865 | mauro.ficaccio@telecomitalia.it | MEREDITH, John M |
| 119 | 12.3 | Charging harmonization for NGN between 3GPP and ATIS-TMOC |  | 51d? | 2006-09-28 A | 2006-12-07 A | 100% |  | 2006-09-28 | 2006-12-07 | 51d? |  | finish no earlier than 2006-12-07 | S5 | 408h | 408h | FBI2-TISP2-CH | Rel-8 | 32.297 |  | Adrian |
| 120 | 12.4 | Deleted - Protocol impact of FBI for TISPAN R2 |  | 152d? | 2006-08-16 | 2007-03-15 |  |  | 2006-08-16 | 2007-03-15 | 152d? | 580d | finish no earlier than 2007-03-15 | C1 | 1216h |  | FBI2-TISP2-c1 | Rel-8 |  |  |  |
| 121 | 12.5 | Deleted (never approved) - Stage 2 of FBI for TISPAN R2 - Rel 8 | milestone | 0d? | 2007-11-30 A | 2007-11-30 A | 100% |  | 2007-04-26 | 2007-11-30 | 157d? |  | finish no earlier than 2007-11-30 | S2 |  |  | FBI2-TISP2-s2 | Rel-8 |  |  |  |
| 122 | 13 | **IMS Centralised Service Control** |  | 266d? | 2007-09-03 A | 2008-09-08 | 51% | 129.71d? | 2007-09-03 | 2007-12-14 | 75d? | 193d |  | S1 | 4264h | 2184.7h | ICSRA | Rel-8 | 22.101 |  |  |
| 123 | 13.1 | Stage 1 for ICSRA |  | 75d? | 2007-09-03 A | 2007-12-14 | 80% | 15d? | 2007-09-03 | 2007-12-14 | 75d? | 384d | finish no earlier than 2007-12-14 | S1 | 600h | 480h | ICSRA-St1 | Rel-8 | 22.101 |  |  |
| 124 | 13.2 | Stage 2 for ICSRA |  | 192d? | 2007-12-14 A | 2008-09-08 | 40% | 115.2d? |  |  |  | 193d | start no earlier than 2007-12-14 | S2 | 1536h | 614.4h | ICSRA-St2 | Rel-8 | 23.206 (Impacts to be determined) |  |  |
| 125 | 14 | AS/MRFC stage 2 and 3 work |  | 218d? | 2007-11-14 | 2008-09-12 |  |  | 2007-11-14 | 2008-09-12 | 218d? | 189d | finish no earlier than 2008-09-12 | C1 | 1744h |  | MRFC_TS | Rel-8 | 23.218, 24.229, 24.147, 24.247 |  | Andrijana |

Notes:
- 99: Text4: Claus Dietze (Giesecke & Devrient)
- 100: C6-43: Name Changed to Requirements for Contact Manager. Expected completion updated from CT#34 to CT#35. / Text4: Claus Dietze (Giesecke & Devrient)
- 101: New TS 31.xyz to be produced / Text4: Claus Dietze (Giesecke & Devrient)
- 102: Created at CT#37 / Text4: Claus Dietze (Giesecke & Devrient)
- 104: Text4: Amar Deol, Nortel Networks
- 105: Text4: Amar Deol, Nortel Networks
- 106: Not reviewed at WG, directly from CT#37 / Text4: Milan Patel (Nortel Networks)
- 107: CT4#32: Crs are presented and in principle agreed, waiting for the approval of stage2...
- 108: Text4: Frank Billenkamp (Nortel Networks)
- 109: is this a one-CR WI? / Text4: Ling Liu, Huawei
- 110: Created by MCC to group 320023 (Stage 1) and 340012 (Stage 3) wrongly shown as idependent Features / Text4: Jim Garrahan (Telcordia)
- 111: Friday check / Text4: Jim Garrahan (Telcordia)
- 112: "CT1" corrected into "C1" / Text4: Keith Drage, Alcatel-Lucent
- 115: Moved to Rel9 / Text4: Tim Haysom (Orange SA), Stefan Bruhn (Telefon AB LM Ericsson)
- 116: Name changed from "System enhancements for TISPAN Rel2" at SA36 / Text4: Steve Tsang-Kwong-U, Orange
- 117: Text4: Delphin Barankanira, Orange
- 118: CP-36: WI approved. C3-36: draft 29.865 advanced. / Text4: Mauro Ficaccio (Telecom Italia)
- 119: 09/2006 SA#33 WID approved / Text4: Amdocs
- 120: To be reviewed in CT1
- 121: It might be more appropriate to introduce the individual functions instead of a global title. SA2 WID expected at SA#36
- 122: Text4: Randy Wohlert (AT&T)
- 123: Text4: Randy Wohlert (AT&T)
- 124: WID Approved at SA#38 / Text4: Andy Bennett (Alcatel-Lucent)
- 125: CT1-50: C1-073183 / Text4: Mark Syrett (Hewlett-Packard)

| ID | WBS | Task | Duration | Start | Finish | Complete | Remaining | Baseline start | Baseline finish | Baseline duration | Total slack | Constraint | Resources | Work | Actual work | Text1 | Text6 | Text3 | Text4 | Text5 | Text8 |
| --- | --- | --- | --- | --- | --- | --- | --- | --- | --- | --- | --- | --- | --- | --- | --- | --- | --- | --- | --- | --- | --- |
| 126 | 15 | **IMS Multimedia Telephony and Supplementary Services** | 421d? | 2007-05-02 A | 2008-12-10 | 20% | 337.82d? | 2007-05-02 | 2009-01-28 | 456d? | 126d |  | C1; C3; S1 | 54024h | 6454.92h | IMSTSS | Rel-8 |  |  |  |  |
| 127 | 15.1 | **General aspects of IMS Sup Services** | 271d? | 2007-09-03 A | 2008-09-15 | 28% | 195.87d? | 2007-09-03 | 2007-12-14 | 75d? | 188d |  | S1; C1; C3; S5 | 16672h | 2652.4h | IMSSS-Gal | Rel-8 |  |  |  |  |
| 128 | 15.1.1 | Service and Capability for Core IMS - inclusion of TISPAN requirements | 75d? | 2007-09-03 A | 2007-12-14 | 90% | 7.5d? | 2007-09-03 | 2007-12-14 | 75d? | 384d | finish no earlier than 2007-12-14 | S1 | 600h | 540h | TISCAPR8 | Rel-8 | 22.228, 22.115, 22.101 | Susana Sabater (Ericsson) |  |  |
| 129 | 15.1.2 | Documentation of 3GPP2 in CT1 | 209d? | 2007-11-28 A | 2008-09-15 | 15% | 177.65d? |  |  |  | 188d | start no earlier than 2007-11-28 | C1 | 1672h | 250.8h | REDOC_3GPP2 | Rel-8 |  | Milo Orsic, Alcatel-Lucent | Milo Orsic, Alcatel-Lucent |  |
| 130 | 15.1.3 | Documentation of 3GPP2 in CT3 | 209d? | 2007-11-28 | 2008-09-15 |  |  |  |  |  | 188d | start no earlier than 2007-11-28 | C3 | 1672h |  | REDOC_3GPP2 | Rel-8 |  | Milo Orsic, Alcatel-Lucent | Milo Orsic, Alcatel-Lucent |  |
| 131 | 15.1.4 | Documentation of 3GPP2 in CT4 | 209d? | 2007-11-28 | 2008-09-15 |  |  |  |  |  | 188d | start no earlier than 2007-11-28 | C4 | 1672h |  | REDOC_3GPP2 | Rel-8 |  | Milo Orsic, Alcatel-Lucent | Milo Orsic, Alcatel-Lucent |  |
| 132 | 15.1.5 | Documentation of TISPAN R1 and R2 in CT1 | 143d? | 2007-11-28 A | 2008-06-15 | 60% | 57.2d? | 2007-11-28 | 2007-12-03 | 4d? | 254d | finish no earlier than 2008-06-15 | C1 | 1144h | 686.4h | REDOC_TIS-C1 | Rel-8 |  | Peter Leis, NSN |  |  |
| 133 | 15.1.6 | Documentation of TISPAN R1 and R2 in CT3 | 143d? | 2007-11-28 A | 2008-06-15 | 30% | 100.1d? | 2007-11-28 | 2007-12-03 | 4d? | 254d | finish no earlier than 2008-06-15 | C3 | 1144h | 343.2h | REDOC_TIS-C3 | Rel-8 |  | Peter Leis, NSN |  |  |
| 134 | 15.1.7 | Documentation of TISPAN R1 and R2 in CT4 | 208d? | 2007-11-28 A | 2008-09-12 | 50% | 104d? | 2007-11-28 | 2007-12-03 | 4d? | 189d | finish no earlier than 2008-09-12 | C4 | 1664h | 832h | REDOC_TIS-C4 | Rel-8 |  |  |  |  |
| 135 | 15.2 | **IMS Multimedia Telephony Service** | 328d? | 2007-09-10 A | 2008-12-10 | 29% | 232.9d? | 2007-09-10 | 2008-12-10 | 328d? | 126d |  | S1; S5 | 6672h | 714.4h | IMS-MMTel | Rel-8 |  |  |  |  |
| 136 | 15.2.1 | Merging TISPAN MMTel [requirements] for Common IMS | 65d? | 2007-09-10 A | 2007-12-07 A | 100% |  | 2007-09-10 | 2007-12-07 | 65d? |  | finish no earlier than 2007-12-07 | S1 | 520h | 520h | TISMMTELR8 | Rel-8 | 22.173 | Joerg Swetina (NSN) |  |  |
| 137 | 15.2.2 | MMTel and Supplementary Services Charging | 243d? | 2008-01-07 A | 2008-12-10 | 10% | 218.7d? | 2008-01-07 | 2008-12-10 | 243d? | 126d | finish no earlier than 2008-12-10 | S5 | 1944h | 194.4h | MMTel-CH | Rel-8 | new 32.275, 32.298/299 | ALU |  | Adrian |
| 138 | 15.3 | **Call Completion on Busy Subscriber (CCBS)/Call Completion on Non-Reachable (CCNR) on IMS** | 304d? | 2007-05-02 A | 2008-06-30 | 4% | 292.06d? | 2007-05-02 | 2008-06-30 | 304d? | 243d |  | C1; C3 | 9640h | 378.49h | CCBS_NR | Rel-8 | 29.163, 24.229, 24.173 | Martin Hülsemann (Deutsche Telekom) |  | Andrijana |
| 139 | 15.3.1 | Stage 3 (CT1) of CCBS/CCNR on IMS | 293d? | 2007-05-02 A | 2008-06-15 | 8% | 269.56d? | 2007-05-02 | 2008-06-30 | 304d? | 254d | finish no earlier than 2008-06-15 | C1 | 2344h | 187.52h | CCBS_NR-C1 | Rel-8 | 29.163, 24.229, 24.173 | Martin Hülsemann (Deutsche Telekom) |  | Andrijana |
| 140 | 15.3.2 | Stage 3 (CT3) of CCBS/CCNR on IMS | 304d? | 2007-05-02 | 2008-06-30 |  |  | 2007-05-02 | 2008-06-30 | 304d? | 243d | finish no earlier than 2008-06-30 | C3 | 2432h |  | CCBS_NR-C3 | Rel-8 | 29.163, 24.229, 24.173 | Martin Hülsemann (Deutsche Telekom) |  | Andrijana |
| 141 | 15.4 | Customised Alerting Tone | 164d? | 2008-01-30 A | 2008-09-15 | 4% | 157.44d? |  |  |  | 188d |  | C1 | 1312h | 52.48h | IMSCAT | Rel-8 |  | Milan Patel, Nortel |  | Andrijana |
| 142 | 15.5 | Flexible Alerting | 164d? | 2008-01-30 A | 2008-09-15 | 4% | 157.44d? |  |  |  | 188d | start no earlier than 2008-01-30 | C1 | 1312h | 52.48h | IMSFA | Rel-8 |  | Milan Patel, Nortel |  | Andrijana |
| 143 | 15.6 | **Communication Wait on IMS** | 211d? | 2007-11-30 A | 2008-09-19 | 4% | 203.62d? | 2007-11-30 | 2009-01-28 | 304d? | 184d |  | C1; C3 | 6752h | 236.32h | CW | Rel-8 | 29.163, 24.229, 24.173 | Martin Hülsemann (Deutsche Telekom) |  | Andrijana |
| 144 | 15.6.1 | Stage 3 (CT1) of CWonIMS | 211d? | 2007-11-30 A | 2008-09-19 | 7% | 196.23d? | 2007-11-30 | 2009-01-28 | 304d? | 184d | finish no earlier than 2008-09-19 | C1 | 1688h | 118.16h | CW-C1 | Rel-8 | 29.163, 24.229, 24.173 | Martin Hülsemann (Deutsche Telekom) |  | Andrijana |
| 145 | 15.6.2 | Stage 3 (CT3) of CWonIMS | 211d? | 2007-11-30 | 2008-09-19 |  |  | 2007-11-30 | 2009-01-28 | 304d? | 184d | finish no earlier than 2008-09-19 | C3 | 1688h |  | ICW-C3 | Rel-8 | 29.163, 24.229, 24.173 | Martin Hülsemann (Deutsche Telekom) |  | Andrijana |
| 146 | 15.7 | Advice of Charge (AoC) support in IMS Charging | 243d? | 2008-01-07 A | 2008-12-10 | 15% | 206.55d? | 2008-01-07 | 2008-12-10 | 243d? | 126d | finish no earlier than 2008-12-10 | S5 | 1944h | 291.6h |  | Rel-8 | new 32.280, 32.240/260/296/298/299 | NSN |  | Adrian |
| 147 | 15.8 | Add Interconnection Border Control Function (IBCF) to IMS Charging | 128d? | 2007-09-17 A | 2008-03-12 A | 100% |  | 2007-09-17 | 2008-09-18 | 264d? |  | finish no earlier than 2008-03-12 | S5 | 1024h | 1024h |  | Rel-8 | 32.240/260/298/299 | ALU |  | Adrian |
| 148 | 16 | Harmonization of Gq'/Rx for Common IMS | 171d? | 2008-01-14 A | 2008-09-08 | 20% | 136.8d? | 2007-09-03 | 2007-12-14 | 75d? | 193d | finish no earlier than 2008-09-08 | S2 | 1368h | 273.6h | IMS_Comm_GqRx_Harm | Rel-8 | 23.8xx, 23 203 | Geoffrey Cristallo (Alcatel-Lucent) | geoffrey.cristallo@alcatel-lucent.be | Maurice |
| 149 | 17 | **Interworking between User-to-User Signaling (UUS) and SIP** | 152d? | 2007-11-30 A | 2008-06-30 | 30% | 106.4d? | 2007-11-30 | 2008-06-30 | 152d? | 243d |  | C1; C3 | 4864h | 1459.2h | UUSIW | Rel-8 | 29.163, 24.279, 24.229 | YANG, Lili (Huawei) |  | Kimmo |
| 150 | 17.1 | Stage 3 (CT1) of UUSIW | 152d? | 2007-11-30 | 2008-06-30 |  |  | 2007-11-30 | 2008-06-30 | 152d? | 243d | start no earlier than 2007-11-30 | C1 | 1216h |  | UUSIW | Rel-8 | 29.163, 24.279, 24.229 | YANG, Lili (Huawei) |  | Kimmo |
| 151 | 17.2 | Stage 3 (CT3) of UUSIW | 152d? | 2007-11-30 A | 2008-06-30 | 60% | 60.8d? | 2007-11-30 | 2008-06-30 | 152d? | 243d | start no earlier than 2007-11-30 | C3 | 1216h | 729.6h | UUSIW | Rel-8 | 29.163, 24.279, 24.229 | YANG, Lili (Huawei) |  | Kimmo |

Notes:
- 137: 12/07 SA#38 WID Approval
- 138: C1-50: C1-073083/C3-071084
- 139: C1-50: C1-073083/C3-071084
- 140: C1-50: C1-073083/C3-071084
- 143: C1-50: C1-073084/C3-071085
- 144: C1-50: C1-073084/C3-071085
- 145: C1-50: C1-073084/C3-071085
- 146: 12/07 SA#38 WID Approval
- 148: WID approved SA#38. per OPs & ETSI GA 39. This is a joint effort of SA WG2 and TISPAN WG2
- 149: C3-46: WID in C1-073199/ C3-071126
- 150: C3-46: WID in C1-073199/ C3-071126
- 151: C3-46: WID in C1-073199/ C3-071126

| ID | WBS | Task | Duration | Start | Finish | Complete | Remaining | Baseline start | Baseline finish | Baseline duration | Total slack | Constraint | Resources | Work | Actual work | Text1 | Text4 | Text6 | Text8 | Text5 |
| --- | --- | --- | --- | --- | --- | --- | --- | --- | --- | --- | --- | --- | --- | --- | --- | --- | --- | --- | --- | --- |
| 152 | 18 | **Support of Overlap signalling** | 126d? | 2007-11-30 A | 2008-05-23 | 2% | 123.48d? | 2007-11-30 | 2008-05-23 | 126d? | 269d |  | C3 | 3024h | 60.48h | Overlap | JESSKE, Roland (Deutsche Telekom) | Rel-8 | MEREDITH, John |  |
| 153 | 18.1 | Stage 3 (CT1) of Overlap | 126d? | 2007-11-30 A | 2008-05-23 | 2% | 123.48d? | 2007-11-30 | 2008-05-23 | 126d? | 269d | finish no earlier than 2008-05-23 | C1 | 1008h | 20.16h | Overlap-C1 | JESSKE, Roland (Deutsche Telekom) | Rel-8 | MEREDITH, John |  |
| 154 | 18.2 | Stage 3 (CT3) of Overlap | 126d? | 2007-11-30 A | 2008-05-23 | 2% | 123.48d? | 2007-11-30 | 2008-05-23 | 126d? | 269d | finish no earlier than 2008-05-23 | C3 | 1008h | 20.16h | Overlap-C3 | JESSKE, Roland (Deutsche Telekom) | Rel-8 | MEREDITH, John |  |
| 155 | 19 | **Maintenance of TISPAN documentation** | 327d? | 2007-07-02 A | 2008-09-30 | 86% | 46.48d? |  |  |  | 177d |  | C1; C3; C4; S2 | 20744h | 13008h | MAINTISP |  | Rel-8 |  |  |
| 156 | 19.1 | Maintenance of TISPAN R1 | 233d? | 2007-11-09 A | 2008-09-30 A | 100% |  | 2007-11-09 | 2008-09-30 | 233d? |  | start no earlier than 2007-11-09 | C1; C3; C4 | 5592h | 5592h | MAINT_R1 | LEIS, Peter (Nokia Siemens Networks) | Rel-7 | Kimmo |  |
| 157 | 19.2 | Maintenance of TISPAN R2 | 233d? | 2007-11-09 A | 2008-09-30 A | 100% |  | 2007-11-09 | 2008-09-30 | 233d? |  | start no earlier than 2007-11-09 | C1; C3; C4 | 5592h | 5592h | MAINT_R2 | LEIS, Peter (Nokia Siemens Networks) | Rel-7 | Kimmo |  |
| 158 | 19.3 | Documentation of TISPAN NGN R1 and R2 in 3GPP SA WG2 | 115d? | 2008-01-14 | 2008-06-20 |  |  | 2007-09-03 | 2007-12-14 | 75d? | 249d | finish no earlier than 2008-06-20 | S2 | 920h |  | IMS_Comm_Doc | Jozsef Varga (Nokia Siemens Networks) | Rel-8 | Maurice | jozsef.varga@nsn.com |
| 159 | 19.4 | Maintenance of TISPAN release 1 common IMS | 114d? | 2007-07-02 A | 2007-12-06 A | 100% |  | 2007-09-03 | 2007-12-14 | 75d? |  | finish no earlier than 2007-12-06 | S2 | 912h | 912h | IMS_Comm_Mtce8 | Antonio Ascolese (Telecom Italia) | Rel-8 | Maurice | antonio.ascolese@telecomitalia.it |
| 160 | 19.5 | Maintenance of TISPAN release 2 common IMS | 114d? | 2007-07-02 A | 2007-12-06 A | 100% |  | 2007-09-03 | 2007-12-14 | 75d? |  | finish no earlier than 2007-12-06 | S2 | 912h | 912h | IMS_Comm_Mtce8 | Antonio Ascolese (Telecom Italia) | Rel-8 | Maurice | antonio.ascolese@telecomitalia.it |
| 161 | 20 | **IMS Service Brokering enhancements** | 69d? | 2005-12-07 A | 2006-03-13 A | 100% |  | 2005-12-07 | 2006-03-13 | 69d? |  |  | S1 | 1104h | 1104h | ISB | John-Luc Bakker (Telcordia) | Rel-8 | Alain | jbakker@telcordia.com |
| 162 | 20.1 | Stage 1 of ISB | 69d? | 2005-12-07 A | 2006-03-13 A | 100% |  | 2005-12-07 | 2006-03-13 | 69d? |  | finish no earlier than 2006-03-13 | S1 | 552h | 552h | ISB-s1 | John-Luc Bakker (Telcordia) | Rel-8 | Alain | jbakker@telcordia.com |
| 163 | 21 | **Security Enhancements for IMS** | 402d? | 2007-03-01 A | 2008-09-12 | 51% | 197.12d? | 2007-03-01 | 2008-09-12 | 402d? | 189d |  | S3 | 8360h | 4260.74h | IMS-Sec | Bengt Sahlin (Ericsson) | Rel-8 | Dioniso |  |
| 164 | 21.1 | SA3 aspects of IMSSec | 272d? | 2007-03-01 A | 2008-03-14 | 43% | 155.04d? | 2007-03-01 | 2008-03-14 | 272d? | 319d | start no earlier than 2007-03-01 | S3 | 2176h | 935.68h | IMS-Sec | Bengt Sahlin (Ericsson) | Rel-8 | Dioniso |  |
| 165 | 21.2 | NASS Bundled Authentication - CT1 part | 218d? | 2007-11-14 A | 2008-09-12 | 30% | 152.6d? | 2007-11-14 | 2008-09-12 | 218d? | 189d | start no earlier than 2007-11-14 | C1 | 1744h | 523.2h | NBA |  | Rel-8 | Andrijana |  |
| 166 | 21.3 | NASS Bundled Authentication - CT4 part | 153d? | 2007-11-14 A | 2008-06-13 | 95% | 7.65d? | 2007-11-14 | 2008-06-13 | 153d? | 254d | start no earlier than 2007-11-14 | C4 | 1224h | 1162.8h | NBA-CT4 |  | Rel-8 |  |  |
| 167 | 22 | **IMS System enhancements for corporate network access** | 326d? | 2007-06-22 A | 2008-09-19 | 8% | 298.46d? | 2007-06-22 | 2008-06-13 | 256d? | 184d |  | S2 | 6912h | 583.92h | IMS_Corp | Delphin Barankanira, Orange | Rel-8 |  |  |
| 168 | 22.1 | IMS System enhancements for corporate network access | 256d? | 2007-06-22 A | 2008-06-13 | 15% | 217.6d? | 2007-06-22 | 2008-06-13 | 256d? | 254d | finish no earlier than 2008-06-13 | S2 | 2048h | 307.2h | IMS_Corp-St2 | Delphin Barankanira, Orange | Rel-8 |  |  |
| 169 | 22.2 | IMS protocol enhancements for corporate network access CT1 | 141d? | 2008-03-07 A | 2008-09-19 | 5% | 133.95d? |  |  |  | 184d | finish no earlier than 2008-09-19 | C1 | 1128h | 56.4h | IMS_Corp-St3_CT1 |  | Rel-8 |  |  |
| 170 | 22.3 | IMS protocol enhancements for corporate network access CT4 | 141d? | 2008-02-26 | 2008-09-19 |  |  |  |  |  | 184d | finish no earlier than 2008-09-19 | C4 | 1128h |  | IMS_Corp-St3_CT4 |  | Rel-8 |  |  |
| 171 | 23 | **IMS Enhancements for support of Packet Cable access** | 398d? | 2006-12-06 A | 2008-06-15 | 82% | 73.56d? | 2006-12-06 | 2008-06-15 | 398d? | 254d |  | S2 | 27384h | 16641.2h | PktCbl |  | Rel-8 | Maurice |  |
| 172 | 23.1 | **IMS Enhancements for Security Requirements in Support of Cable Deployments** | 393d? | 2006-12-06 A | 2008-06-06 | 95% | 17.92d? | 2006-12-06 | 2008-03-15 | 333d? | 259d |  | S3 | 11432h | 7910h | PktCbl-Sec | Steve Dotson (Cablelabs) | Rel-8 | Dioniso | s.dotson@cablelabs.com |
| 173 | 23.1.1 | S3 Aspects of PktCbl-Sec | 272d? | 2006-12-06 A | 2007-12-20 A | 100% |  | 2006-12-06 | 2007-12-20 | 272d? |  | finish no earlier than 2007-12-20 | S3 | 2176h | 2176h | PktCbl-Sec | Steve Dotson (Cablelabs) | Rel-8 | Dioniso | s.dotson@cablelabs.com |
| 174 | 23.1.2 | CT1 Aspects of PktCbl-Sec | 315d? | 2007-03-26 A | 2008-06-06 | 85% | 47.25d? | 2007-03-26 | 2008-03-15 | 255d? | 259d | finish no earlier than 2008-06-06 | C1 | 2520h | 2142h | PktCbl-Sec | David Hancock (CableLabs) | Rel-8 | Andrijana | D.Hancock@ CableLabs.com |
| 175 | 23.1.3 | CT3 Aspects of PktCbl-Sec | 194d? | 2007-03-26 A | 2007-12-20 A | 100% |  | 2007-03-26 | 2008-03-15 | 255d? |  | finish no earlier than 2008-03-15 | C3 | 1552h | 1552h | PktCbl-Sec | David Hancock (CableLabs) | Rel-8 |  | D.Hancock@ CableLabs.com |
| 176 | 23.1.4 | CT4 Aspects of PktCbl-Sec | 255d? | 2007-03-26 A | 2008-03-14 A | 100% |  | 2007-03-26 | 2008-03-14 | 255d? |  | finish no earlier than 2008-03-14 | C4 | 2040h | 2040h | PktCbl-Sec | David Hancock (CableLabs) | Rel-8 | Kimmo | D.Hancock@ CableLabs.com |

Notes:
- 152: C3-46: WID in C1-073126 / C3-071127 /C4-072008. / Text3: 29.163, 24.229, 29.228, 29.229
- 153: C3-46: WID in C1-073126 / C3-071127 /C4-072008. / Text3: 29.163, 24.229, 29.228, 29.229
- 154: C3-46: WID in C1-073126 / C3-071127 /C4-072008. / Text3: 29.163, 24.229, 29.228, 29.229
- 156: C3-46: WID in C1-073189 / C3-071114 / C4-072032. / Text3: 24.229, 24.127, 29.162, 29.163, 29.228, 29.229, 24.xxx
- 157: C3-46: WID in C1-073189 / C3-071114 / C4-072032. / Text3: 24.229, 24.127, 29.162, 29.163, 29.228, 29.229, 24.xxx
- 158: WID approved SA#38. per OPs & ETSI GA 39. This is a joint effort of SA WG2 and TISPAN WG2 / Text3: 23.xxx, 23.228, 23.204, 23.167, 23.xyz (TBD)
- 159: WID and TSs approved at SA#38 / Text3: 23.517 (ETSI ES 282.007), 23.506 (ETSI TS 182.006), 23.521 (ETSI TS 182.021), 23.507 (ETSI TS 182.007)
- 160: WID and TSs approved at SA#38 / Text3: 23.517 (ETSI ES 282.007), 23.506 (ETSI TS 182.006), 23.521 (ETSI TS 182.021), 23.507 (ETSI TS 182.007)
- 161: Text3: 22.228
- 162: Text3: 22.228
- 163: WID approved at SP-36 / Text3: 33.203, 33.828, 33.803
- 164: WID approved at SP-36 / Text3: 33.203, 33.828, 33.803
- 165: Text3: 24.229
- 166: Text3: 29.229, 29.228, 23.008
- 169: Text3: 24.229
- 170: Text3: 29.228, 29.229, 23.003, 23.008
- 172: Text3: 33.203, 33.210, 33.220, 24.229
- 173: Text3: 33.203, 33.210, 33.220, 24.229
- 174: Supporting Companies: / Text3: 24.229, 24.109
- 175: Added as 100% complete at CT#38 / Text3: 24.229, 24.109
- 176: Supporting Companies: / Text3: 29.228, 29229, 23.008,

| ID | WBS | Task | Type | Duration | Start | Finish | Complete | Remaining | Baseline start | Baseline finish | Baseline duration | Total slack | Constraint | Resources | Work | Actual work | Text1 | Text6 | Text3 | Text4 | Text5 | Text8 |
| --- | --- | --- | --- | --- | --- | --- | --- | --- | --- | --- | --- | --- | --- | --- | --- | --- | --- | --- | --- | --- | --- | --- |
| 177 | 23.2 | **IMS Enhancements for Cable Client Types and Deployment Models** |  | 355d? | 2007-02-05 A | 2008-06-15 | 40% | 211.94d? | 2007-02-05 | 2008-06-15 | 355d? | 254d |  | S2 | 7128h | 1930.35h | PktCbl-Deploy | Rel-8 |  |  |  |  |
| 178 | 23.2.1 | Architecture aspects of PktCbl-Deploy |  | 216d? | 2007-02-05 A | 2007-12-03 A | 100% |  | 2007-02-05 | 2007-12-03 | 216d? |  | finish no earlier than 2007-12-03 | S2 | 1728h | 1728h | PktCbl-Deploy | Rel-8 |  |  |  |  |
| 179 | 23.2.2 | CT1 aspects of PktCbl-Deploy |  | 320d? | 2007-03-26 | 2008-06-15 |  |  | 2007-03-26 | 2008-06-15 | 320d? | 254d | finish no earlier than 2008-06-15 | C1 | 2560h |  | PktCbl-Deploy | Rel-8 | 24.229, 24167 | David Hancock (CableLabs) | D.Hancock@ CableLabs.com | Andrijana |
| 180 | 23.3 | **IMS Inter-working Aspects in Support of Cable Regulatory requirements** |  | 290d? | 2007-02-05 A | 2008-03-15 | 99% | 0d? | 2007-02-05 | 2008-03-15 | 290d? | 0d |  | S2 | 5640h | 4205.29h | PktCbl-Intw | Rel-8 | 23.228 | Bernie McKibben (CableLabs) | B.McKibben@CableLabs.com | Maurice |
| 181 | 23.3.1 | Architecture aspects of PktCbl-Interwork |  | 160d? | 2007-02-05 A | 2007-09-14 A | 100% |  | 2007-02-05 | 2007-09-14 | 160d? |  | start no earlier than 2007-02-05 | S2 | 1280h | 1280h | PktCbl-Intw | Rel-8 | 23.228 | Bernie McKibben (CableLabs) | B.McKibben@CableLabs.com | Maurice |
| 182 | 23.3.2 | CT1 aspects of PktCbl-Interwork |  | 255d? | 2007-03-26 A | 2008-03-15 A | 100% |  | 2007-03-26 | 2008-03-15 | 255d? |  | finish no earlier than 2008-03-15 | C1 | 2040h | 2040h | PktCbl-Intw | Rel-8 | 24.229 | David Hancock (CableLabs) | D.Hancock@ CableLabs.com | Andrijana |
| 183 | 24 | **eCall Data Transfer** |  | 307d? | 2006-09-28 A | 2007-11-30 | 80% | 61.4d? | 2006-09-28 | 2007-11-30 | 307d? | 394d |  | S1 | 4912h | 3929.6h | EData | Rel-8 | 22.101, 22.105 | Rhys Robinson (Airbiquity) | rrobinson@airbiquity.com | Alain |
| 184 | 24.1 | eData Requirements |  | 307d? | 2006-09-28 A | 2007-11-30 | 80% | 61.4d? | 2006-09-28 | 2007-11-30 | 307d? | 394d | finish no earlier than 2006-12-07 | S1 | 2456h | 1964.8h | EData | Rel-8 | 22.101, 22.105 | Rhys Robinson (Airbiquity) | rrobinson@airbiquity.com | Alain |
| 185 | 25 | Local Charging Zone Requirements |  | 51d? | 2006-09-28 A | 2006-12-07 A | 100% |  | 2006-09-28 | 2006-12-07 | 51d? |  | finish no earlier than 2006-12-07 | S1 | 408h | 408h | LCZR | Rel-8 | 22.115 | Hong Liu (China Mobile) | liuhongyfw@chinamobile.com | Alain |
| 186 | 26 | Services Alignment and Migration |  | 323d? | 2006-12-06 A | 2008-02-29 | 80% | 64.6d? | 2006-12-06 | 2008-02-29 | 323d? | 329d | finish no earlier than 2008-02-29 | S1 | 2584h | 2067.2h | ServAl | Rel-8 | 22.182 | Feng Lingjuan (China Mobile) | fenglingjuan@chinamobile.com | Alain |
| 187 | 27 | Value Added Services for Short Message Service |  | 140d? | 2007-09-10 A | 2008-03-21 | 70% | 42d? | 2007-09-10 | 2008-03-21 | 140d? | 314d | finish no earlier than 2008-03-21 | S1 | 1120h | 784h | VAS4SMS | Rel-8 | 22.142 | Wu Bin (China Mobile) | wubin@chinamobile.com |  |
| 188 | 28 | **Customised Alerting Tone** |  | 264d? | 2006-12-06 A | 2007-12-10 A | 100% |  | 2006-12-06 | 2007-12-10 | 264d? |  |  | S1 | 4336h | 4336h | CAT | Rel-8 | 22.182 | Feng Lingjuan (China Mobile) | (fenglingjuan@chinamobile.com) | Alain |
| 189 | 28.1 | Stage 1 for CAT |  | 207d? | 2006-12-06 A | 2007-09-20 A | 100% |  | 2006-12-06 | 2007-09-20 | 207d? |  | start no earlier than 2006-12-06 | S1 | 1656h | 1656h | CAT | Rel-8 | 22.182 | Feng Lingjuan (China Mobile) | (fenglingjuan@chinamobile.com) | Alain |
| 190 | 28.2 | Customized multimedia information services - inclusion of TISPAN requirements |  | 71d? | 2007-09-03 A | 2007-12-10 A | 100% |  | 2007-09-03 | 2007-12-10 | 71d? |  | finish no earlier than 2007-12-10 | S1 | 568h | 568h | TISCMI | Rel-8 | 22.182 | Peter Bleckert (Ericsson) |  |  |
| 191 | 29 | **I-WLAN Network Selection Principle** |  | 270d? | 2007-09-03 A | 2008-09-12 | 1% | 268.03d? | 2007-09-03 | 2007-09-03 | 1d? | 189d |  | S1 | 3256h | 16h | IWLANNSP | Rel-8 | 22.234 | Chris Friel (O2) | chris.friel@o2.com | Alain |
| 192 | 29.1 | Stage 1 of I-WLAN NSP |  | 1d? | 2007-09-03 A | 2007-09-03 A | 100% |  | 2007-09-03 | 2007-09-03 | 1d? |  |  | S1 | 8h | 8h | IWLANNSP-St1 | Rel-8 | 22.234 | Chris Friel (O2) | chris.friel@o2.com | Alain |
| 193 | 29.2 | Stage 3 of WLAN NSP |  | 136d? | 2008-03-07 | 2008-09-12 |  |  |  |  |  | 189d | finish no earlier than 2008-09-12 | C1 | 1088h |  | IWLANNSP-St3 | Rel-8 | 24.234 |  |  |  |
| 194 | 30 | **Interworking Wireless LAN Mobility** |  | 257d? | 2007-09-14 A | 2008-09-08 | 55% | 115.65d? | 2007-09-14 | 2008-06-13 | 196d? | 193d |  | S2 | 4112h | 2261.6h | IWLAN_Mob | Rel-8 | 23.xxx | Xiaobao Chen, Orange | xiaobao.chen@orange-ftgroup.com | Maurice |
| 195 | 30.1 | Stage 2: Interworking Wireless LAN Mobility |  | 257d? | 2007-09-14 A | 2008-09-08 | 55% | 115.65d? | 2007-09-14 | 2008-06-13 | 196d? | 193d | finish no earlier than 2008-09-08 | S2 | 2056h | 1130.8h | IWLAN_Mob | Rel-8 |  |  |  |  |
| 196 | 31 | **Service-Level Interworking for Messaging Services** |  | 249d? | 2007-03-26 A | 2008-03-07 | 99% | 0d? | 2007-03-26 | 2008-03-07 | 249d? | 0d |  | S1 | 3808h | 2872h | MESSIW | Rel-8 | 22.105, 22.340, 23.204, 23.811 | Liu Ling (Huawei); Duan Xiaoqin (Huawei) | ling.liu@huawei.com; duanxiaoqin@huawei.com | Alain |
| 197 | 31.1 | Stage 1 aspects of MESSIW | milestone | 0d? | 2007-03-26 A | 2007-03-26 A | 100% |  | 2007-03-26 | 2007-03-26 | 0d? |  | finish no earlier than 2007-12-01 | S1 |  |  | MESSIW-St1 | Rel-8 | 22.105, 22.340 | Liu Ling (Huawei) | ling.liu@huawei.com | Alain |
| 198 | 31.2 | Stage 2 aspects of MESSIW |  | 227d? | 2007-04-26 A | 2008-03-07 A | 100% |  | 2007-04-26 | 2008-03-07 | 227d? |  | finish no earlier than 2008-03-07 | S2 | 1816h | 1816h | MESSIW-St2 | Rel-8 | 22.105, 22.340, 23.204, 23.811 | Patrice Hede (Huawei) | patrice.hede@huawei.com | Maurice |
| 199 | 32 | **OAM&P 8** |  | 402d? | 2007-06-07 A | 2008-12-19 | 45% | 219.94d? | 2006-09-22 | 2008-12-12 | 581d? | 119d |  | S5 | 37697.5h | 13661.1h | OAM8 | Rel-8 |  |  |  | Adrian |
| 200 | 32.1 | **Network Infrastructure Management 8** |  | 396d? | 2007-06-07 A | 2008-12-11 | 48% | 206.83d? | 2007-06-07 | 2008-12-11 | 396d? | 125d |  | S5 | 16944h | 7856.34h |  | Rel-8 |  |  |  | Adrian |
| 201 | 32.1.1 | Telecom Management Methodology |  | 396d? | 2007-06-07 A | 2008-12-11 | 65% | 138.6d? | 2007-06-07 | 2008-12-11 | 396d? | 125d | finish no earlier than 2008-12-11 | S5 | 3168h | 2059.2h |  | Rel-8 | new 32.155 , 32.153 | Ericsson |  |  |
| 202 | 32.1.2 | Advanced Alarming on Itf-N (Study + Implementation) |  | 396d? | 2007-06-07 A | 2008-12-11 | 80% | 79.2d? | 2007-06-07 | 2008-03-06 | 196d? | 125d | finish no earlier than 2008-12-11 | S5 | 3168h | 2534.4h |  | Rel-8 | new 32.121/2/3 | NSN |  |  |
| 203 | 32.1.3 | CN CS Bearer Transport Network (BTN) relative NRM |  | 396d? | 2007-06-07 A | 2008-12-11 | 30% | 277.2d? | 2007-06-07 | 2008-03-06 | 196d? | 125d | finish no earlier than 2008-12-11 | S5 | 3168h | 950.4h |  | Rel-8 | 32.632/3/5 | China Mobile |  |  |
| 204 | 32.1.4 | End point modelling for reference point |  | 324d? | 2007-09-17 A | 2008-12-11 | 40% | 194.4d? | 2007-09-17 | 2008-03-06 | 124d? | 125d | finish no earlier than 2008-12-11 | S5 | 2592h | 1036.8h |  | Rel-8 | 32.152, 32.62/3/4x, 32.73x | Motorola |  |  |
| 205 | 32.1.5 | Alignment with eTOM and M.3060 architectural concepts |  | 210d? | 2008-02-22 | 2008-12-11 |  |  | 2007-09-17 | 2008-03-06 | 124d? | 125d | start no earlier than 2008-02-22 | S5 | 1680h |  |  | Rel-8 | 32.101/2, 32.xyz | TeliaSonera |  |  |

Notes:
- 179: Supporting Companies:
- 180: Supporting Companies: CableLabs, Nortel, Cisco, Samsung, Alcatel-Lucent, Siemens, Motorola, Hewlett-Packard, Ericsson
- 181: Supporting Companies: CableLabs, Nortel, Cisco, Samsung, Alcatel-Lucent, Siemens, Motorola, Hewlett-Packard, Ericsson
- 182: Supporting Companies:
- 184: SA4 related activity - to be checked
- 186: previous names were Services Alignment, Service Migration
- 188: Acronym changed from "CusAlert" to "CAT"
- 194: Name changed before SA#38 (was "Mobility between 3GPP-WLAN Interworking and 3GPP Systems")
- 196: WID updated by S2-57, Approved at SP-36
- 198: WID updated by S2-57, Approved at SP-36. Rapporteur updated S2#59. TR for Information to SA#38
- 199: Created to encompass the Rel7 Work Tasks shifted to Rel8
- 200: Created to encompass the Rel7 Work Tasks shifted to Rel8
- 205: SA#39 WID Approval

| ID | WBS | Task | Type | Duration | Start | Finish | Complete | Remaining | Baseline start | Baseline finish | Baseline duration | Total slack | Constraint | Resources | Work | Actual work | Text6 | Text8 | Text4 | Text1 | Text5 | Text7 |
| --- | --- | --- | --- | --- | --- | --- | --- | --- | --- | --- | --- | --- | --- | --- | --- | --- | --- | --- | --- | --- | --- | --- |
| 206 | 32.2 | **Performance Management 8** |  | 396d? | 2007-06-07 A | 2008-12-11 | 50% | 198d? | 2007-06-07 | 2008-09-11 | 331d? | 125d |  | S5 | 12672h | 4760h | Rel-8 | Adrian |  |  |  |  |
| 207 | 32.2.1 | IP bearer network Performance measurement definitions |  | 396d? | 2007-06-07 A | 2008-12-11 | 40% | 237.6d? | 2007-06-07 | 2008-03-06 | 196d? | 125d | finish no earlier than 2008-12-11 | S5 | 3168h | 1267.2h | Rel-8 |  | China Mobile |  |  |  |
| 208 | 32.2.2 | HSUPA performance measurements |  | 396d? | 2007-06-07 A | 2008-12-11 | 70% | 118.8d? | 2007-06-07 | 2008-03-06 | 196d? | 125d | finish no earlier than 2008-12-11 | S5 | 3168h | 2217.6h | Rel-8 |  | China Mobile |  |  |  |
| 209 | 32.2.3 | Key Performance Indicators (KPIs) for UMTS/GERAN |  | 396d? | 2007-06-07 A | 2008-12-11 | 40% | 237.6d? | 2007-06-07 | 2008-09-11 | 331d? | 125d | finish no earlier than 2008-12-11 | S5 | 3168h | 1267.2h | Rel-8 |  | China Mobile |  |  |  |
| 210 | 32.3 | **Trace Management 8** |  | 324d? | 2007-09-17 A | 2008-12-11 | 40% | 194.4d? | 2007-09-17 | 2008-09-11 | 259d? | 125d |  | S5 | 5184h | 1044.8h | Rel-8 |  |  |  |  |  |
| 211 | 32.3.1 | Subscriber and Equipment Trace for eUTRAN and EPC |  | 324d? | 2007-09-17 A | 2008-12-11 | 40% | 194.4d? | 2007-09-17 | 2008-09-11 | 259d? | 125d | finish no earlier than 2008-12-11 | S5 | 2592h | 1036.8h | Rel-8 |  | Ericsson |  |  |  |
| 212 | 32.4 | Service Level Tracing in IMS |  | 180.18d? | 2008-03-07 A | 2008-12-19 |  | 180.18d? | 2006-09-22 | 2008-12-12 | 555.18d? | 119d | finish no earlier than 2008-12-19 | C1 | 1441.46h |  | Rel-8 | Andrijana | Jari Jansson, Nokia | OAM8-Trace | jari.jansson@nokia.com |  |
| 213 | 33 | **Registration in Densely-populated area** |  | 391d? | 2007-03-12 A | 2008-09-08 | 51% | 192.42d? | 2007-03-12 | 2008-06-13 | 330d? | 193d |  | S1 | 5160h | 1060.8h | Rel-8 | Alain | Tsuyoshi Takakura (NTT DoCoMo Inc.) | RED | takakurat@s1.nttdocomo.co.jp |  |
| 214 | 33.1 | Stage 1 for RED |  | 4d? | 2007-03-12 A | 2007-03-15 A | 100% |  | 2007-03-12 | 2007-03-15 | 4d? |  | start no earlier than 2007-03-12 | S1 | 32h | 32h | Rel-8 | Alain | Tsuyoshi Takakura (NTT DoCoMo Inc.) | RED | takakurat@s1.nttdocomo.co.jp |  |
| 215 | 33.2 | Stage2 for Registration in Densely-populated area (RED) |  | 250d? | 2007-09-25 A | 2008-09-08 | 50% | 125d? | 2007-09-25 | 2008-06-13 | 189d? | 193d | finish no earlier than 2008-09-08 | S2 | 2000h | 1000h | Rel-8 | Maurice | Itsuma Tanaka (NTT DoCoMo Inc.) | RED-St2 | tanakai@nttdocomo.co.jp |  |
| 216 | 34 | Lawful Interception in the 3GPP Rel-8 |  | 265d? | 2007-03-12 A | 2008-03-14 | 20% | 212d? | 2007-03-12 | 2008-03-14 | 265d? | 319d | finish no earlier than 2008-03-14 | S3 | 2120h | 424h | Rel-8 | Dioniso | Berthold Wilhelm (BMWi/BNetzA) | LI8 | berthold.wilhelm@bnetza.de |  |
| 217 | 35 | **Rel-8 Improvements of the Radio Interface** |  | 532d? | 2007-03-05 A | 2009-03-17 | 35% | 344.21d? | 2007-03-05 | 2008-05-15 | 314d? | 57d |  | RP | 20872h | 6729.6h | Rel-8 | Claude |  | RInImp8 |  |  |
| 218 | 35.1 | UMTS 1500 MHz |  | 140d? | 2007-03-05 A | 2007-09-14 A | 100% |  | 2007-03-05 | 2007-09-14 | 140d? |  | finish no earlier than 2007-09-14 | R4 | 1120h | 1120h | Rel-8 | Claude | Takehiro Nakamura | RInImp8-UMTS1500 | NTT DoCoMo | TSG |
| 219 | 35.2 | UMTS 700 MHz |  | 334d? | 2007-03-05 A | 2008-06-12 | 70% | 100.2d? | 2007-03-05 | 2007-12-28 | 215d? | 255d | finish no earlier than 2008-06-12 | R4 | 2672h | 1870.4h | Rel-8 | Claude | Tuomo Saynajakangas | RInImp8-UMTS700 | Nokia | TSG |
| 220 | 35.3 | UMTS 2300 MHz |  | 334d? | 2007-03-05 A | 2008-06-12 | 10% | 300.6d? | 2007-03-05 | 2007-12-28 | 215d? | 255d | finish no earlier than 2008-06-12 | R4 | 2672h | 267.2h | Rel-8 | Claude | Marc Grant | RInImp8-UMTS2300 | marc.grant@cingular.com | TSG |
| 221 | 35.4 | UMTS/LTE 3500 MHz |  | 327d? | 2007-12-17 | 2009-03-17 |  |  |  |  |  | 57d | finish no earlier than 2009-03-17 | R4 | 2616h |  | Rel-8 | Claude | Johan Sköld, Ericsson | RInImp8-UMTSLTE3500 | johan.skold@ericsson.com |  |
| 222 | 35.5 | UMTS 2300 MHz TDD |  | 327d? | 2007-12-17 | 2009-03-17 |  |  |  |  |  | 57d | finish no earlier than 2009-03-17 | R4 | 2616h |  | Rel-8 | Claude | Yuexia Song, Datang | RInImp8-UMTS2300TDD | songyuexia@datangmobile.cn |  |
| 223 | 35.6 | Further Improved Minimum Performance Requirements for HSDPA UE (FDD) - Two-Branch Interference Cancellation |  | 268d? | 2007-03-05 A | 2008-03-12 | 80% | 53.6d? | 2007-03-05 | 2007-12-28 | 215d? | 321d | finish no earlier than 2008-03-12 | R4 | 2144h | 1715.2h | Rel-8 | MCC_RAN | Marc Grant, Cingular | RInImp8-2BIC | marc.grant@cingular.com |  |
| 224 | 35.7 | CS Voice Service over HSPA |  | 172d? | 2007-07-19 A | 2008-03-14 | 10% | 154.8d? | 2007-07-19 | 2008-03-14 | 172d? | 319d | start no earlier than 2007-07-19 | R2 | 1376h | 137.6h | Rel-8 | MCC_RAN | Woonhee Hwang, Nokia Siemens Networks | RInImp8-CsHspa | woonhee.hwang@nsn.com |  |
| 225 | 35.8 | Performance requirements for 15 code reception with 16QAM/QPSK |  | 195d? | 2007-06-11 A | 2008-06-12 | 52% | 93.6d? | 2007-09-14 | 2008-05-15 | 175d? | 255d | finish no earlier than 2008-06-12 | R4 | 1560h | 811.2h | Rel-8 | MCC_RAN | Tim Frost, Vodafone | RInImp8-Hsdpa15codes | tim.frost@vodafone.com |  |
| 226 | 36 | **Personal Network Management** |  | 835d? | 2005-07-11 A | 2008-09-19 | 58% | 350.82d? | 2005-07-11 | 2008-09-19 | 835d? | 184d |  | S1 | 18956.8h | 10332.2h | Rel-8 | Alain | Armin Toepfer, Vodafone | PNM | armin.toepfer@vodafone.com |  |
| 227 | 36.1 | Stage 1 of PNM |  | 276d? | 2005-07-11 A | 2006-07-31 A | 100% |  | 2005-07-11 | 2006-07-31 | 276d? |  | start no earlier than 2005-07-11 | S1 | 2208h | 2208h | Rel-8 | Alain |  | PNM |  |  |
| 228 | 36.2 | Stage 2 of PNM |  | 320d? | 2007-03-26 A | 2008-06-15 | 95% | 16d? | 2007-03-26 | 2008-03-26 | 263d? | 254d | finish no earlier than 2008-06-15 | C1 | 2560h | 2432h | Rel-8 | Andrijana | Yang Lu (Vodafone) | PNM | yang.lu@vodafone.com |  |
| 229 | 36.3 | **Stage 3 of PNM** |  | 390d? | 2007-03-26 A | 2008-09-19 | 25% | 294.45d? | 2007-03-26 | 2008-09-19 | 390d? | 184d |  | C1 | 7571.2h | 1854.94h | Rel-8 | Andrijana | Yang Lu (Vodafone) | PNM | yang.lu@vodafone.com |  |
| 230 | 36.3.1 | CT1 aspects of PNM |  | 390d? | 2007-03-26 A | 2008-09-19 | 40% | 234d? | 2007-03-26 | 2008-09-19 | 390d? | 184d | finish no earlier than 2008-09-19 | C1 | 3120h | 1248h | Rel-8 | Andrijana | Yang Lu (Vodafone) | PNM | yang.lu@vodafone.com |  |
| 231 | 36.3.2 | CT4 aspects of PNM |  | 310d? | 2007-03-26 A | 2008-05-30 | 5% | 294.5d? | 2007-03-26 | 2008-03-26 | 263d? | 264d | finish no earlier than 2008-05-30 | C4 | 2480h | 124h | Rel-8 |  | Yang Lu, | PNM |  |  |
| 232 | 36.4 | Deleted - Actual Requirements of PNM | milestone | 0d? | 2007-03-26 A | 2007-03-26 A | 100% |  | 2007-03-26 | 2007-03-26 | 0d? |  | finish no earlier than 2007-03-26 | C1 |  |  | Rel-8 |  |  | PNM |  |  |

Notes:
- 206: Created to encompass the Rel7 Work Tasks shifted to Rel8
- 207: Text3: 32.321/2/3/5
- 208: Text3: 32.405
- 209: Text3: 32.xyz
- 210: Created to encompass the Rel7 Work Tasks shifted to Rel8
- 211: Text3: 32.42x, 32.44x
- 212: Cannot proceed without substancial IETF contribution / Text3: 24.229, 24.167, 29.228,29.229,29.163,29.332
- 213: One CR at SA #35 / Text3: 22.101
- 214: One CR at SA #35 / Text3: 22.101
- 215: Approved as BB at SP-37 / Text3: 23.880
- 216: End date to be determined when Rel-8 frozen. / Text3: 33.106, 33.107, 33.108
- 218: Text3: TS25.101, TS25.104, TS25.133, TS25.141, TS25.331, TS25.942, TS25.306, TS25.307, TS34.121
- 219: Text3: TS25.101, TS25.104, TS25.133, TS25.141, TS25.331, TS25.942, TS25.306, TS25.307, TS34.121
- 220: Text3: TS25.101, TS25.104, TS25.133, TS25.141, TS25.331, TS25.942, TS25.306, TS25.307, TS34.121
- 221: Text3: 25.101, 25.104, 25.113, 25.133, 25.141, 34.124, 25.307, 25.331, 25.461, 25.463, 34.108, 34.121, 36.101, 36.104, 36.141, 36.508, 25.307, 36.331, 36.521-1, 36.521-2
- 222: Text3: 25.102, 25.105, 25.113, 25.123, 25.142, 34.124, 25.306, 25.331, 34.122
- 224: Text3: 25.323, 25.331, 25.322
- 225: Text3: 25.101
- 226: Moved from FS section Feb 06. SP-33: Create new section to capture the PNM stage 2 aspects and identify any impacts to existing stage 2 specifications. S2 added as secondary responsibility
- 227: Moved from FS section Feb 06: SP-33: Create new section to capture the PNM stage 2 aspects and identify any impacts to existing stage 2 specifications. / Text3: 22.259, 23.818
- 228: Text3: 23.259
- 229: Moved from FS section Feb 06: SP-33: Create new section to capture the PNM stage 2 aspects and identify any impacts to existing stage 2 specifications.
- 230: Text3: 24.229, 24.259
- 231: Text3: 23.008, 23.018, 29.002, 29.328, 29.329

| ID | WBS | Task | Duration | Start | Finish | Complete | Remaining | Baseline start | Baseline finish | Baseline duration | Total slack | Constraint | Resources | Work | Actual work | Text1 | Text4 | Text6 | Text8 | Text7 | Text5 |
| --- | --- | --- | --- | --- | --- | --- | --- | --- | --- | --- | --- | --- | --- | --- | --- | --- | --- | --- | --- | --- | --- |
| 233 | 37 | **Charging Management small Enhancements** | 716d? | 2006-03-16 A | 2008-12-11 | 70% | 218.11d? | 2006-03-16 | 2008-12-10 | 715d? | 125d |  | S5 | 11760h | 4460.67h | CH8 | Orange | Rel-8 | Adrian |  |  |
| 234 | 37.1 | Online charging correlation | 420d? | 2006-03-16 A | 2007-12-14 A | 100% |  | 2006-03-16 | 2007-12-14 | 420d? |  | finish no earlier than 2007-12-14 | S5 | 3360h | 3360h |  | Orange | Rel-8 |  |  |  |
| 235 | 37.2 | SMS online charging | 137d? | 2007-06-07 A | 2007-12-14 A | 100% |  | 2007-06-07 | 2007-12-14 | 137d? |  | finish no earlier than 2007-12-14 | S5 | 1096h | 1096h |  | Vodafone | Rel-8 |  |  |  |
| 236 | 37.3 | WLAN Offline Charging | 244d? | 2008-01-07 | 2008-12-11 |  |  | 2008-01-07 | 2008-06-12 | 114d? | 125d | finish no earlier than 2008-12-11 | S5 | 1952h |  |  | ALU | Rel-8 |  |  |  |
| 237 | 38 | **OSA Rel-8** | 336d? | 2007-08-23 A | 2008-12-04 | 10% | 301.15d? | 2007-08-23 | 2008-12-04 | 336d? | 130d |  | S1 | 34544h | 3465.97h | OSA8 | Orange | Rel-8 | Alain | TSG |  |
| 238 | 38.1 | OSA Stage 1 - Service Requirements | 74d? | 2007-08-23 A | 2007-12-04 A | 100% |  | 2007-08-23 | 2007-12-04 | 74d? |  | finish no earlier than 2007-12-04 | S1 | 592h | 592h | OSA8 |  | Rel-8 | Alain | TSG |  |
| 239 | 38.2 | OSA Stage 1 - NGN Service Requirement | 140d? | 2007-09-03 A | 2008-03-14 A | 100% |  | 2007-09-03 | 2008-03-14 | 140d? |  | finish no earlier than 2008-03-14 | S1 | 1120h | 1120h | OSA8-IMS | Song Dong (Orange) | Rel-8 |  |  |  |
| 240 | 38.3 | **OSA Stage 2/3 enhancements** | 291d? | 2007-10-25 A | 2008-12-04 | 5% | 275.45d? | 2007-10-25 | 2008-12-04 | 291d? | 130d |  | C5 | 32832h | 1753.97h | OSA8 | Orange | Rel-8 | Adrian |  |  |
| 241 | 38.3.1 | Ensure Parlay-X composable with identity management frameworks, in particular Liberty Alliance | 291d? | 2007-10-25 | 2008-12-04 |  |  | 2007-10-25 | 2008-12-04 | 291d? | 130d | finish no earlier than 2008-12-04 | C5 | 2328h |  |  | Ericsson, FT/Orange, Sprint, Telecom Italia | Rel-8 |  |  |  |
| 242 | 38.3.2 | Parlay-X Content Management web service (store/manage meta-data) | 291d? | 2007-10-25 | 2008-12-04 |  |  | 2007-10-25 | 2008-12-04 | 291d? | 130d | finish no earlier than 2008-12-04 | C5 | 2328h |  |  | ETRI | Rel-8 |  |  |  |
| 243 | 38.3.3 | Parlay-X Policy web service | 291d? | 2007-10-25 A | 2008-12-04 | 70% | 87.3d? | 2007-10-25 | 2008-12-04 | 291d? | 130d | finish no earlier than 2008-12-04 | C5 | 2328h | 1629.6h |  | ETRI | Rel-8 |  |  |  |
| 244 | 38.3.4 | Parlay-X Terminal status web service | 291d? | 2007-10-25 | 2008-12-04 |  |  | 2007-10-25 | 2008-12-04 | 291d? | 130d | finish no earlier than 2008-12-04 | C5 | 2328h |  |  | Orange | Rel-8 |  |  |  |
| 245 | 38.3.5 | Identify communication format used by a particular application | 291d? | 2007-10-25 | 2008-12-04 |  |  | 2007-10-25 | 2008-12-04 | 291d? | 130d | finish no earlier than 2008-12-04 | C5 | 2328h |  |  | AePONA | Rel-8 |  |  |  |
| 246 | 38.3.6 | Security on User Profile Management - reuse GUP API (22.127 CR 0084 S1-071794) | 262d? | 2007-12-05 | 2008-12-04 |  |  |  |  |  | 130d | finish no earlier than 2008-12-04 | C5 | 2096h |  |  | Telecom Italia | Rel-8 |  |  |  |
| 247 | 38.3.7 | Privacy on Subscriber Identity (Liberty Alliance, OASIS) (22.127 CR 0085 S1-071835) | 262d? | 2007-12-05 | 2008-12-04 |  |  |  |  |  | 130d | finish no earlier than 2008-12-04 | C5 | 2096h |  |  | Telecom Italia | Rel-8 |  |  |  |
| 248 | 38.3.8 | Topology Hiding (22.127 CR 0086 S1-071838) | 262d? | 2007-12-05 | 2008-12-04 |  |  |  |  |  | 130d | finish no earlier than 2008-12-04 | C5 | 2096h |  |  | Telecom Italia | Rel-8 |  |  |  |
| 249 | 38.3.9 | Subscriber event notification (22.127 CR 0087 S1-071836) | 262d? | 2007-12-05 | 2008-12-04 |  |  |  |  |  | 130d | finish no earlier than 2008-12-04 | C5 | 2096h |  |  | Telecom Italia | Rel-8 |  |  |  |
| 250 | 38.3.10 | Event notification (22.127 CR 0088 S1-071762) | 262d? | 2007-12-05 | 2008-12-04 |  |  |  |  |  | 130d | finish no earlier than 2008-12-04 | C5 | 2096h |  |  | Telecom Italia | Rel-8 |  |  |  |
| 251 | 38.3.11 | Access policy (22.127 CR 0089 S1-071763) | 262d? | 2007-12-05 | 2008-12-04 |  |  |  |  |  | 130d | finish no earlier than 2008-12-04 | C5 | 2096h |  |  | Telecom Italia | Rel-8 |  |  |  |
| 252 | 38.3.12 | API usage accounting (22.127 CR 0090 S1-071792) | 262d? | 2007-12-05 | 2008-12-04 |  |  |  |  |  | 130d | finish no earlier than 2008-12-04 | C5 | 2096h |  |  | Telecom Italia | Rel-8 |  |  |  |
| 253 | 38.3.13 | Presence alignment with OMA and IETF (22.127 CR 0092 S1-071764) | 262d? | 2007-12-05 | 2008-12-04 |  |  |  |  |  | 130d | finish no earlier than 2008-12-04 | C5 | 2096h |  |  | Ericsson | Rel-8 |  |  |  |
| 254 | 38.3.14 | Service identification (22.127 CR 0095 S1-071837) | 262d? | 2007-12-05 | 2008-12-04 |  |  |  |  |  | 130d | finish no earlier than 2008-12-04 | C5 | 2096h |  |  | Ericsson | Rel-8 |  |  |  |
| 255 | 39 | **Rel-8 RAN improvements** | 329d? | 2007-06-04 A | 2008-09-04 | 28% | 237.77d? | 2007-06-04 | 2008-09-12 | 335d? | 195d |  | RP | 15056h | 4174.77h | RANimp |  | Rel-8 |  |  |  |
| 256 | 39.1 | Combination of 64QAM and MIMO for HSDPA (FDD) | 201d? | 2007-06-04 A | 2008-03-10 | 82% | 36.18d? | 2007-06-04 | 2008-03-10 | 201d? | 323d | finish no earlier than 2008-03-10 | R1 | 1608h | 1318.56h | RANimp-64QamMimoHsdpa | Johan Bergman, Ericsson | Rel-8 | MCC_RAN |  | Johan.Bergman@ericsson.com |
| 257 | 39.2 | Improved L2 for uplink | 127d? | 2007-09-14 A | 2008-03-10 | 50% | 63.5d? | 2007-09-14 | 2008-03-10 | 127d? | 323d | start no earlier than 2007-09-14 | R2 | 1016h | 508h | RANimp-UplinkL2dataRates | Janne Peisa, Ericsson | Rel-8 | MCC_RAN |  | Janne.Peisa@ericsson.com |
| 258 | 39.3 | Enhanced Uplink for CELL_FACH State in FDD | 195d? | 2007-09-14 A | 2008-06-12 | 30% | 136.5d? | 2007-09-14 | 2008-05-15 | 175d? | 255d | finish no earlier than 2008-06-12 | R2 | 1560h | 468h | RANimp-UplinkEnhState | Markus Wimmer, Nokia Siemens Networks | Rel-8 | MCC_RAN |  | markus.wimmer@nsn.com |
| 259 | 39.4 | Enhanced UE DRX for FDD | 195d? | 2007-09-14 A | 2008-06-12 | 20% | 156d? | 2007-09-14 | 2008-09-12 | 261d? | 255d | finish no earlier than 2008-06-12 | R2 | 1560h | 312h | RANimp-DRX | Luís Barreto, Nokia | Rel-8 | MCC_RAN |  | luis.barreto@nokia.com |
| 260 | 39.5 | Enhancements for SRNS Relocation Procedure | 131d? | 2007-09-14 A | 2008-03-14 | 30% | 91.7d? | 2007-09-14 | 2008-03-14 | 131d? | 319d | finish no earlier than 2008-03-14 | R3 | 1048h | 314.4h | RANimp-SrnsReloc | Masatoshi Nakamata, Nokia Siemens Networks | Rel-8 | MCC_RAN |  | masatoshi.nakamata@nsn.com |
| 261 | 39.6 | Enhancements for FDD HSPA Evolution | 131d? | 2007-09-14 A | 2008-03-14 | 50% | 65.5d? | 2007-09-14 | 2008-03-14 | 131d? | 319d | finish no earlier than 2008-03-14 | R3 | 1048h | 524h | RANimp-HSPAEvo | Masatoshi Nakamata, Nokia Siemens Networks | Rel-8 | MCC_RAN |  | masatoshi.nakamata@nsn.com |
| 262 | 39.7 | 64QAM for 1.28 Mcps TDD HSDPA | 117d? | 2007-12-04 | 2008-05-14 |  |  |  |  |  | 276d | finish no earlier than 2008-05-14 | R1 | 936h |  | RANimp-64Qam1.28TDD | Zhifeng Ma, ZTE | Rel-8 | MCC_RAN |  | zfmail@zte.com.cn |
| 263 | 39.8 | Enhanced CELL_FACH state in 1.28 Mcps TDD | 198d? | 2007-12-04 | 2008-09-04 |  |  |  |  |  | 195d | finish no earlier than 2008-09-04 | R2 | 1584h |  | RANimp-EnhState1.28TDD | Yincheng Zhang, ZTE | Rel-8 | MCC_RAN |  | zhang.yincheng@zte.com.cn |
| 264 | 39.9 | 1.28 Mcps TDD TDD Repeater Specification | 117d? | 2007-12-04 | 2008-05-14 |  |  |  |  |  | 276d | finish no earlier than 2008-05-14 | R4 | 936h |  | RANimp-Repeaters1.28TDD | Qin Yan, RITT | Rel-8 | MCC_RAN |  | qinyan@chinattl.com |
| 265 | 39.10 | MBSFN Downlink Optimised Broadcast 3.84 Mcps TDD | 141d? | 2007-06-04 | 2007-12-17 |  |  |  |  |  | 383d | finish no earlier than 2007-12-17 | R1 | 1128h |  | MBSFN-DOB | Lars Lindbom (Ericsson) | Rel-8 | MCC_RAN |  |  |

Notes:
- 233: Text3: 32.2xy
- 234: WID approved SA#35 / Text3: 32.240, 32.296
- 235: Text3: new 32.274, CR 32.240 / 299/ 298
- 236: 12/07 SA#38 WID Approval / Text3: 32.252/298/299
- 238: az: WID URL corrected / Text3: 22.127
- 239: Text3: 22.127
- 240: Text3: 23.198, 29.198/9
- 241: Text3: 29.199-xy
- 242: Text3: 29.199-NEW
- 243: Text3: 29.199-22
- 244: Text3: 29.199-NEW
- 245: Text3: 29.199-xy
- 256: Text3: 25.308,25.211,25.212,25.213,25.306,25.331,25.433,25.435,25.423,25.425,25.101,25.104,25.141
- 257: Text3: 25.319, 25.301, 25.306, 25.321, 25.331, 25.433, 25.435, 25.423, 25.425, 25.427
- 258: Text3: 25.309, 25.211, 25.214, 25.321, 25.331, 25.423, 25.433
- 259: Text3: 25.306, 25.308, 25.321, 25.331, 25.423
- 260: Text3: 25.306, 25.308, 25.321, 25.331, 25.423, 25.433, 25.214, 25.133
- 261: Text3: 25.423, 25.427, 25.433
- 262: Text3: 25.201, 25.221, 25.222, 25.223, 25.224, 25.306, 25.308, 25.321, 25.331, 25.423, 25.433, 25.102, 25.105, 25.142
- 263: Text3: 25.308, 25.304, 25.306, 25.224, 25.321, 25.331, 25.433, 25.435, 25.423, 25.425, 25.123
- 264: Text3: TS 25.113
- 265: Moved from Rel-7 / Text3: 25.346, 25.201,25.221,25.222,25.223,25.306,25.331,25.402,25.433,25.102,25.105,25.123

| ID | WBS | Task | Duration | Start | Finish | Complete | Remaining | Baseline start | Baseline finish | Baseline duration | Total slack | Constraint | Resources | Work | Actual work | Text1 | Text4 | Text5 | Text6 | Text8 | Text3 | Text7 |
| --- | --- | --- | --- | --- | --- | --- | --- | --- | --- | --- | --- | --- | --- | --- | --- | --- | --- | --- | --- | --- | --- | --- |
| 266 | 40 | **Support of (G)MSC-S – (G)MSC-S Nc Interface based on the SIP-I protocol** | 266d? | 2007-09-14 A | 2008-09-19 | 47% | 141.87d? | 2007-09-14 | 2008-09-19 | 266d? | 184d |  | C4 | 8512h | 3972.27h | SIP_Nc | David Hutton (Vodafone Group) | David.Hutton@VODAFONE.COM | Rel-8 | Kimmo |  |  |
| 267 | 40.1 | SIP-I based circuit-switched core network; Stage 2 | 266d? | 2007-09-14 A | 2008-09-19 | 70% | 79.8d? | 2007-09-14 | 2008-09-19 | 266d? | 184d | finish no earlier than 2008-09-19 | C4 | 2128h | 1489.6h | SIP_Nc-St2 |  |  | Rel-8 | Kimmo | TS 23.231 |  |
| 268 | 40.2 | Application of SIP-I Protocols to Circuit Switched (CS) core network architecture; Stage 3 | 266d? | 2007-09-14 A | 2008-09-19 | 60% | 106.4d? | 2007-09-14 | 2008-09-19 | 266d? | 184d | finish no earlier than 2008-09-19 | C4 | 2128h | 1276.8h | SIP_Nc-St3 |  |  | Rel-8 | Kimmo | TS 29.231 |  |
| 269 | 40.3 | Interworking between the 3GPP CS domain with SIP-I as signalling protocol and other networks | 266d? | 2007-09-14 A | 2008-09-19 | 10% | 239.4d? | 2007-09-14 | 2008-09-19 | 266d? | 184d | finish no earlier than 2008-09-19 | C3 | 2128h | 212.8h | SIP_Nc-IW |  |  | Rel-8 | MEREDITH, John M | 29.235 |  |
| 270 | 41 | IMS Stage-3 IETF Protocol Alignment | 387d? | 2007-06-22 A | 2008-12-15 | 20% | 309.6d? | 2007-06-22 | 2008-12-15 | 387d? | 123d | finish no earlier than 2008-12-15 | C1 | 3096h | 619.2h | IMSProtoc2 | Keith Drage (Alcatel-Lucent) | drage@alcatel-lucent.com | Rel-8 | Andrijana | 23.218, 24.229 |  |
| 271 | 42 | New multicarrier BTS class | 186d? | 2007-08-31 A | 2008-05-16 | 70% | 55.8d? | 2007-08-31 | 2008-02-22 | 126d? | 274d | finish no earlier than 2008-05-16 | G1 | 1488h | 1041.6h | MCBTS | Thomas BITZER (Alcatel-Lucent) | thomas.bitzer@alcatel-lucent.de | Rel-8 | Paolo | 45.005, 45.050, 51.021 |  |
| 272 | 43 | MS Antenna Performance Evaluation Method and Requirements | 731d? | 2005-01-28 A | 2007-11-16 A | 100% |  | 2005-01-28 | 2007-11-16 | 731d? |  | finish no earlier than 2007-11-16 | GP | 5848h | 5848h | APEMR | Ulf.Tegth (TeliaSonera) | Ulf.Tegth@teliasonera.com | Rel-8 | Paolo | 25.914, 25.144, 45.005 |  |
| 273 | 44 | DELETE U-TDOA Enhancement | 131d? | 2007-05-18 A | 2007-11-16 A | 100% |  | 2007-05-18 | 2007-11-16 | 131d? |  | finish no earlier than 2007-11-16 | GP | 1048h | 1048h | GUTEN | Ms. Terri L. Brooks, TruePosition, Inc. | terri.brooks@trueposition.com | Rel-7 | Paolo | 43.059, 45.008, 48.071 |  |
| 274 | 45 | **Paging Permission with Access Control** | 264d? | 2007-06-12 A | 2008-06-14 | 38% | 163.75d? | 2007-06-12 | 2008-03-14 | 199d? | 254d |  | S1 | 3888h | 1226.4h | PPACR | Morita Takashi, NTT DoCoMo Inc. |  | Rel-8 | Alain | 22.011 |  |
| 275 | 45.1 | Stage 1 of PPACR | 69d? | 2007-06-12 A | 2007-09-14 A | 100% |  | 2007-06-12 | 2007-09-14 | 69d? |  | finish no earlier than 2007-09-14 | S1 | 552h | 552h | PPACR-S1 | Morita Takashi, NTT DoCoMo Inc. |  | Rel-8 | Alain | 22.011 |  |
| 276 | 45.2 | Stage 3 (CT1) of PPACR | 153d? | 2007-11-14 A | 2008-06-14 | 10% | 137.7d? | 2007-11-14 | 2008-03-14 | 88d? | 254d | finish no earlier than 2008-06-14 | C1 | 1224h | 122.4h | PPACR-CT1 | Morita Takashi, NTT DoCoMo Inc. |  | Rel-8 | Andrijana | 24.008, 23.122 |  |
| 277 | 46 | **GAN Enhancements** | 261d? | 2007-08-31 A | 2008-08-29 | 36% | 167.22d? | 2007-08-31 | 2008-08-29 | 261d? | 199d |  | GP | 5184h | 1112.4h | GANENH | Mohammed Versi, T-Mobile USA Inc. | mohammed.versi@t-mobile.com | Rel-8 | Paolo | 43.318, 44.318, 51.010 |  |
| 278 | 46.1 | Update to GAN specifications | 126d? | 2007-08-31 A | 2008-02-22 A | 100% |  | 2007-08-31 | 2008-02-22 | 126d? |  | finish no earlier than 2008-02-22 | GP | 1008h | 1008h | GANENH-SPEC | Mohammed Versi, T-Mobile USA Inc. | mohammed.versi@t-mobile.com | Rel-8 | Paolo, Gert | 43.318, 44.318 |  |
| 279 | 46.2 | Update TS 51.010 Mobile Station (MS) Conformance Specification for GAN Enhancements | 261d? | 2007-08-31 A | 2008-08-29 | 5% | 247.95d? | 2007-08-31 | 2008-08-29 | 261d? | 199d | finish no earlier than 2008-08-29 | GP | 2088h | 104.4h | GANENH-MStest | Mohammed Versi, T-Mobile USA Inc. | mohammed.versi@t-mobile.com | Rel-8 | Stoyan | 51.010 |  |
| 280 | 47 | **Earthquake and Tsunami Warning System** | 261d? | 2007-09-10 A | 2008-09-08 | 59% | 107.86d? | 2007-09-10 | 2008-03-10 | 131d? | 193d |  | S1 | 4504h | 2642.74h | ETWS | Ryo Kitahara (NTTDoCoMo) | kitaharar@nttdocomo.co.jp | Rel-8 | Alain |  |  |
| 281 | 47.1 | Stage 1 for ETWS | 131d? | 2007-09-10 A | 2008-03-10 | 70% | 39.3d? | 2007-09-10 | 2008-03-10 | 131d? | 323d | finish no earlier than 2008-03-10 | S1 | 1048h | 733.6h | ETWS-S1 | Ryo Kitahara (NTTDoCoMo) | kitaharar@nttdocomo.co.jp | Rel-8 | Alain | 22.268 |  |
| 282 | 47.2 | Stage 2 for ETWS | 171d? | 2008-01-14 A | 2008-09-08 | 50% | 85.5d? |  |  |  | 193d | finish no earlier than 2008-09-08 | S2 | 1368h | 684h | ETWS-S2 | Itsuma Tanaka (NTTDoCoMo) | tanakai@nttdocomo.co.jp | Rel-8 | Maurice | 23.8xx |  |
| 283 | 48 | **Multimedia interworking between IMS and CS networks** | 846d? | 2005-09-23 A | 2008-12-19 | 57% | 361.33d? | 2005-09-23 | 2008-12-19 | 846d? | 119d |  | C3 | 11224h | 2596.23h | MIWIMS | Nico Gabriele, Vodafone UK | nico.gabriele@vodafone.com | Rel-8 | Seung Don | 29.163, 29.332 |  |
| 284 | 48.1 | Note: Stages 1 and 2 defined in earlier Release | 49d? | 2005-09-23 A | 2005-11-30 A | 100% |  | 2005-09-23 | 2005-11-30 | 49d? |  | start no earlier than 2005-09-23 | S2 | 392h | 392h |  |  |  | Rel-8 |  |  |  |
| 285 | 48.2 | Stage 3 of MW-IMS, MONA extension | 225d? | 2007-11-05 A | 2008-09-12 | 32% | 153d? | 2007-11-05 | 2008-12-09 | 287d? | 189d | finish no earlier than 2008-09-12 | C3 | 1800h | 576h | MWIMS-St3Ph2 |  |  | Rel-8 | MEREDITH, John M | 29.163 |  |
| 286 | 48.3 | Mn interface (MGCF – IM MGW) | 283d? | 2007-11-21 A | 2008-12-19 | 70% | 84.9d? | 2007-11-21 | 2008-12-19 | 283d? | 119d | finish no earlier than 2008-12-19 | C4 | 2264h | 1584.8h | MWIMS-Mn |  |  | Rel-8 |  | 29.332 |  |
| 287 | 49 | **Conferencing enhancements for Mp interface** | 266d? | 2007-11-30 A | 2008-12-05 | 9% | 242.47d? | 2007-11-30 | 2008-12-05 | 266d? | 129d |  | C4 | 5944h | 525.86h | eMp | Chen cheng | Chencheng@huawei.com | Rel-8 | Kimmo | 23.333, 29.333 |  |
| 288 | 49.1 | Stage 2 of eMp | 211d? | 2007-11-30 A | 2008-09-19 | 20% | 168.8d? | 2007-11-30 | 2008-09-19 | 211d? | 184d | finish no earlier than 2008-09-19 | C4 | 1688h | 337.6h | eMp | Chen cheng | Chencheng@huawei.com | Rel-8 | Kimmo | 23.333 |  |
| 289 | 49.2 | Stage 3 of eMp | 266d? | 2007-11-30 | 2008-12-05 |  |  | 2007-11-30 | 2008-12-05 | 266d? | 129d | finish no earlier than 2008-12-05 | C4 | 2128h |  | eMp | Chen cheng | Chencheng@huawei.com | Rel-8 | Kimmo | 29.333 |  |
| 290 | 50 | Access Security Enhancements | 152d? | 2007-07-02 A | 2008-01-29 | 75% | 38d? | 2007-07-02 | 2008-01-29 | 152d? | 352d | start no earlier than 2007-07-01 | S3 | 1216h | 912h | ACCSEC2 | Bengt Sahlin, Ericsson | Bengt.Sahlin@ericsson.com | Rel-8 | Michael | 33.102, 43.020 | TSG |
| 291 | 51 | MTSI Video - Dynamic Rate Adaptation/Signalling of Image Size | 206d? | 2007-12-06 A | 2008-09-18 | 10% | 185.4d? |  |  |  | 185d | finish no earlier than 2008-09-18 | S4 | 1648h | 164.8h | MTSIV_DRASIS | Nikolai Leung, Qualcomm Europe & Kyunghun Jung, Samsung | nleung@qualcomm.com & kyunghun.jung@samsung.com | Rel-8 | Paolo | 26.114 |  |
| 292 | 52 | eCall data transfer Phase 2: Comparison of alternative in-band modem solutions and standardization of one in-band modem solution | 391d? | 2007-12-06 A | 2009-06-04 | 10% | 351.9d? |  |  |  | 0d | finish no earlier than 2009-06-04 | S4 | 3128h | 312.8h | eCall_Phase2 | Leon Hong & Rhys Robinson, Airbiquity | lhong@airbiquity.com & rrobinson@airbiquity.com | Rel-8 | Paolo | TS 26.xxx, TR 26.9xx |  |
| 293 | 53 | Extending PSS and MBMS User Services for optimized Mobile TV | 266d? | 2007-12-06 A | 2008-12-11 | 5% | 252.7d? |  |  |  | 125d | finish no earlier than 2008-12-11 | S4 | 2128h | 106.4h | PSS_MBMS_OMTV | Thorsten Lohmar, Telefon AB LM Ericsson | thorsten.lohmar@ericsson.com | Rel-8 | Paolo | 26.234, 26.346, 26.946 |  |
| 294 | 54 | Storage and easy access of In Case of Emergency numbers on USIM | 71d? | 2007-12-06 | 2008-03-13 |  |  |  |  |  | 320d | finish no earlier than 2008-03-13 | S1 | 568h |  | ICE |  |  | Rel-8 |  |  |  |

Notes:
- 269: CP-37: WI corrected. C3-36: Skeleton of TR 29.235 available.
- 272: Reference to RAN4 specifications containing performance evaluation method included in Rel 7. GSM MS requirements open.
- 273: Included in Rel7
- 274: Forgotten after SA#36
- 275: Forgotten after SA#36
- 276: CT1-50: C1-072820
- 277: Completed
- 278: Completed
- 279: Not completed
- 282: Stage 2 added at SA#38: Stage 2 TR is a temporary solution placeholder TR
- 283: C3-36: Rel-8 stage 3 (MONA) extension added, so Feature moved to Rel-8 (all Rel-7 aspects completed); revised WID in C3-071150.
- 284: Moved from FS section Feb 06
- 285: C3-46: New stage 3 element to cater for MONA extension.
- 290: Moved from Rel-7 to Rel-8 at SA#38

| ID | WBS | Task | Type | Duration | Start | Finish | Complete | Remaining | Baseline start | Baseline finish | Baseline duration | Total slack | Constraint | Resources | Work | Actual work | Text1 | Text6 | Text8 | Text12 | Text7 |
| --- | --- | --- | --- | --- | --- | --- | --- | --- | --- | --- | --- | --- | --- | --- | --- | --- | --- | --- | --- | --- | --- |
| 295 | 55 | **IP Interconnection of Services** |  | 71d? | 2007-12-06 | 2008-03-13 |  |  |  |  |  | 320d |  | S1 | 1136h |  | IPinterc | Rel-8 |  |  |  |
| 296 | 55.1 | Stage 1 for Ipinterc |  | 71d? | 2007-12-06 | 2008-03-13 |  |  |  |  |  | 320d | start no earlier than 2007-12-06 | S1 | 568h |  | IPinterc | Rel-8 |  |  |  |
| 297 | 56 | Network Selection for non-3GPP Access |  | 71d? | 2007-12-06 | 2008-03-13 |  |  |  |  |  | 320d | start no earlier than 2007-12-06 | S1 | 568h |  | N3GTONSP | Rel-8 |  |  |  |
| 298 | 57 | **Charging for multi-phases services** |  | 71d? | 2007-12-06 | 2008-03-13 |  |  |  |  |  | 320d |  | S1 | 1136h |  | CHRGMPH | Rel-8 |  |  |  |
| 299 | 57.1 | Stage 1 for CHRGMPH |  | 71d? | 2007-12-06 | 2008-03-13 |  |  |  |  |  | 320d | start no earlier than 2007-12-06 | S1 | 568h |  | CHRGMPH-s1 | Rel-8 |  |  |  |
| 300 | 58 | Support for IMS Emergency Calls over GPRS and EPS |  | 171d? | 2008-01-14 A | 2008-09-08 | 25% | 128.25d? | 2007-09-03 | 2007-12-14 | 75d? | 193d | finish no earlier than 2008-09-08 | S2 | 1368h | 342h | IMS_EMER_GPRS_EPS | Rel-8 | Maurice |  |  |
| 301 | 59 | **Home NodeB / eNodeB** |  | 71d? | 2007-12-06 | 2008-03-13 |  |  |  |  |  | 320d |  | S1 | 1136h |  | HomeNB | Rel-8 |  |  |  |
| 302 | 59.1 | Stage 1 for HNB_eHNB |  | 71d? | 2007-12-06 | 2008-03-13 |  |  |  |  |  | 320d | start no earlier than 2007-12-06 | S1 | 568h |  | HomeNB-S1 | Rel-8 |  |  |  |
| 303 | 60 | Customized Ringing Signal |  | 71d? | 2007-12-06 | 2008-03-13 |  |  |  |  |  | 320d | start no earlier than 2007-12-06 | S1 | 568h |  | CRS | Rel-8 |  |  |  |
| 304 | 61 | **Conformance testing for the Latency Reductions feature** |  | 196d? | 2008-02-22 | 2008-11-21 |  |  |  |  |  | 139d |  | G1; G3 | 4224h |  | CTLATRED | Rel-8 | Paolo, Stoyan |  |  |
| 305 | 61.1 | MS conformance testing for the Latency Reductions feature |  | 196d? | 2008-02-22 | 2008-11-21 |  |  |  |  |  | 139d | finish no earlier than 2008-11-21 | G3 | 1568h |  | CTLATRED-MStest | Rel-8 | Stoyan |  |  |
| 306 | 61.2 | BTS conformance testing for the Latency Reductions feature |  | 136d? | 2008-02-22 | 2008-08-29 |  |  |  |  |  | 199d | finish no earlier than 2008-08-29 | G1 | 1088h |  | CTLATRED-BTStest | Rel-8 | Paolo |  |  |
| 307 | 62 | Mobile Station conformance testing of Packet-switched Handover |  | 196d? | 2008-02-22 | 2008-11-21 |  |  |  |  |  | 139d | finish no earlier than 2008-11-21 | G3 | 1568h |  | PSHCT_MStest | Rel-8 | Stoyan |  |  |
| 308 | 63 | Mobile Station conformance testing of Support of Conversational Services in A/Gb mode via the PS domain |  | 321d? | 2008-02-22 | 2009-05-15 |  |  |  |  |  | 14d | finish no earlier than 2009-05-15 | G3 | 2568h |  | SCSAGBCT_MStest | Rel-8 | Stoyan |  |  |
| 309 | 64 | AoIP (A-interface over IP) |  | 196d? | 2008-02-22 | 2008-11-21 |  |  |  |  |  | 139d | start no earlier than 2008-02-22 | GP, G2 | 1568h |  | AoIP | Rel-8 | Paolo, Gert |  |  |
| 310 | 65 | Definition of 3GPP UICC services over the new high-speed interface |  | 200d? | 2007-12-10 | 2008-09-12 |  |  |  |  |  | 189d | finish no earlier than 2008-09-12 | C6 | 1600h |  | UICCHS | Rel-8 | Xavier |  |  |
| 311 | 66 | (Small) Technical Enhancements and Improvements for Rel-8 |  | 400d? | 2007-01-01 | 2008-07-11 |  |  | 2007-01-01 | 2008-07-11 | 400d? | 234d | start no earlier than 2007-01-01 | All | 3200h |  | TEI8 | Rel-8 |  |  |  |
| 312 | 67 | Deleted - was Rel7 - LCS for 3GPP Interworking WLAN | milestone | 0d? | 2007-09-28 | 2007-09-28 |  |  | 2007-09-28 | 2007-09-28 | 0d? | 439d | start no earlier than 2007-09-28 | S2 |  |  | LCS4_IWLAN | Rel-8 | Maurice | S2-56 |  |
| 313 | 68 | Deleted - never approved- FBI Phase 2 | milestone | 0d | 2007-09-28 | 2007-09-28 |  |  | 2007-09-28 | 2007-09-28 | 0d | 439d | start no earlier than 2007-09-28 | S2 |  |  | FBI2 | Rel-8 | Maurice |  | TSG |
| 314 | 69 | Abandoned -Enhancements to BS30 Bearer service for Videotelephony | milestone | 0d? | 2007-03-15 A | 2007-03-15 A | 100% |  | 2007-03-15 | 2007-03-15 | 0d? |  | finish no earlier than 2007-03-15 | S1 |  |  | BS30 | Rel-8 | Alain |  |  |
| 315 | 70 | Deleted - IMS Enhancements Rel-8 |  | 75d? | 2007-09-03 A | 2007-12-14 | 83% | 13.08d? | 2007-09-03 | 2007-12-14 | 75d? | 384d |  | S1 | 600h | 495.35h | IMS8 | Rel-8 |  |  |  |
| 316 | 71 | Rel-8 Feasibility Studies |  | 1104d? | 2004-06-28 A | 2008-09-18 | 57% | 470.08d? | 2004-06-28 | 2008-09-18 | 1104d? | 185d |  | CT;RAN;SA | 8832h | 5071.4h |  | Rel-8 |  |  |  |
| 317 | 72 | Study on Facilitating Machine to Machine Communication in GSM and UMTS (M2M) |  | 161d? | 2005-11-04 A | 2006-06-16 A | 100% |  | 2005-11-04 | 2006-06-16 | 161d? |  | finish no earlier than 2006-06-16 | S1 | 1288h | 1288h | M2M | Rel-8 | Alain |  |  |
| 318 | 73 | Study on Network Composition |  | 211d? | 2005-12-07 A | 2006-09-27 A | 100% |  | 2005-12-07 | 2006-09-27 | 211d? |  | finish no earlier than 2006-09-27 | S1 | 1688h | 1688h | NetComp | Rel-8 | Alain |  |  |
| 319 | 74 | Study on Charging Aspects of 3GPP System Evolution |  | 179d? | 2007-04-02 A | 2007-12-06 A | 100% |  | 2007-04-02 | 2007-12-06 | 179d? |  | finish no earlier than 2007-12-06 | S5 | 1432h | 1432h | FSSAEcharg | Rel-8 |  | SP-32 |  |
| 320 | 75 | Study on Stage 2 aspects of IMS Service Brokering |  | 581d? | 2006-06-19 A | 2008-09-08 | 55% | 261.45d? | 2006-06-19 | 2008-06-13 | 520d? | 193d | finish no earlier than 2008-09-08 | S2 | 4648h | 2556.4h | ISB_ST2_SDY | Rel-8 | Maurice |  |  |
| 321 | 76 | Study of Requirements of IMS Multimedia Conferencing |  | 205d? | 2006-06-08 A | 2007-03-21 A | 100% |  | 2006-06-08 | 2007-03-21 | 205d? |  | finish no earlier than 2007-03-21 | S1 | 1640h | 1640h | SI-IMSconf | Rel-8 | Alain |  |  |
| 322 | 77 | Study on Protection against SMS and MMS spam |  | 402d? | 2006-06-08 A | 2007-12-21 | 10% | 361.8d? | 2006-06-08 | 2007-12-21 | 402d? | 379d | finish no earlier than 2007-12-21 | S3 | 3216h | 321.6h | CPSMal | Rel-8 | Dioniso |  |  |
| 323 | 78 | Study of VCC support for Emergency Calls |  | 657d? | 2006-06-08 A | 2008-12-12 | 35% | 427.05d? | 2006-06-08 | 2008-06-20 | 532d? | 124d | finish no earlier than 2008-12-12 | S2 | 5256h | 1839.6h | FSVCCEm | Rel-8 | Maurice |  |  |

Notes:
- 300: WID approved SA#38 / Text3: 23.8xx, 22.101, 23.060, 23.167, 23.228, 23.271, 23.203, 23.401, 23.402, 23.221 / Text4: Deborah Barclay (Alcatel-Lucent)
- 304: Text3: 51.010, 51.021 / Text4: Mats Samuelsson, Telefon AB LM Ericsson and Håkan Grunditz, Telefon AB LM Ericsson / Text5: mats.y.samuelsson@ericsson.com and hakan.e.grunditz@ericsson.com
- 305: Text3: 51.010 / Text4: Håkan Grunditz, Telefon AB LM Ericsson / Text5: hakan.e.grunditz@ericsson.com
- 306: Text3: 51.021 / Text4: Mats Samuelsson, Telefon AB LM Ericsson / Text5: mats.y.samuelsson@ericsson.com
- 307: Text3: 51.010 / Text4: Franz Segerer, Rohde & Schwarz / Text5: Franz.Segerer@ROHDE-SCHWARZ.COM
- 308: Text3: 51.010 / Text4: Arsi Heino, NOKIA Corporation / Text5: arsi.heino@nokia.com
- 309: Text3: 48.001, 48.002, 48.008, 48.020, 49.008 / Text4: Wang Shuaiyu, China Mobile and Paul Schliwa-Bertling, Telefon AB LM Ericsson / Text5: wangshuaiyu@chinamobile.com and paul.schliwa-bertling@ericsson.com
- 310: Text4: Jacques Seif (Gemalto) / Text5: jacques.seif@gemalto.com
- 312: New WID approved SP-34. Supporting companies: Telcordia, Samsung, Qualcomm, BT, LG Electronics, Cingular, Alcatel-Lucent. No scheduled end date! / Text3: 23.234, 23.271, 23.167 / Text4: Donghee Shim (LG Electronics Inc.) / Text5: dhshim@lge.com
- 313: Added by MCC as a consequence of the move to Rel8 of TISPAN Rel-2 impacts on 3GPP
- 314: Text3: 22.002, 22.004, 22.101, 22.105, 24.008 / Text4: Andre Jarvis (3) / Text5: andre.jarvis@three.co.uk
- 315: Created by SA1 Chair and MCC to group all the IMS-related enhancements
- 317: Text3: 22.868 / Text4: Juergen Merkel, Siemens AG
- 318: Text3: 22.980 / Text4: Joerg Swetina (Siemens) / Text5: joerg.swetina@siemens.com
- 319: WID approved SA#35 / Text3: TR 32.820 / Text4: NSN
- 320: Study approved SA#32 / Text3: 23.810 / Text4: Raquel Morera (Telcordia); F. Joe Lin (Telcordia) / Text5: raquel@research.telcordia.com
- 321: Text3: 22.948 / Text4: Zheng Jianping (China Mobile ) / Text5: zhengjianping@chinamobile.com
- 322: Formerly called "Consumer protection against spam and malware" / Text3: 33.9xx / Text4: Eric Gauthier (Orange SA) / Text5: eric.gauthier@orange.ch
- 323: Rapporteur update S2#59 / Text3: 23.826 / Text4: Ricky Kaura, Nortel

| ID | WBS | Task | Duration | Start | Finish | Complete | Remaining | Baseline start | Baseline finish | Baseline duration | Total slack | Constraint | Resources | Work | Actual work | Text1 | Text3 | Text4 | Text5 | Text6 | Text8 | Text12 |
| --- | --- | --- | --- | --- | --- | --- | --- | --- | --- | --- | --- | --- | --- | --- | --- | --- | --- | --- | --- | --- | --- | --- |
| 324 | 79 | **Study on centralized IMS services** | 349d? | 2006-10-23 A | 2008-02-21 | 97% | 11.15d? | 2006-10-23 | 2007-12-01 | 290d? | 335d |  | S1; S2 | 8520h | 6937.04h | FSICS | 22.892, 23.892 | Peter Bleckert, Ericsson | peter.bleckert@ericsson.com | Rel-8 |  |  |
| 325 | 79.1 | Study on centralized IMS services requirements | 192d? | 2007-03-05 A | 2007-11-27 | 91% | 17.28d? | 2007-03-05 | 2007-11-27 | 192d? | 397d | start no earlier than 2007-03-05 | S1 | 1536h | 1397.76h | FSICS-S1 | 22.892, 23.892 | Peter Bleckert, Ericsson | peter.bleckert@ericsson.com | Rel-8 |  |  |
| 326 | 79.2 | Study on centralized IMS services control | 349d? | 2006-10-23 A | 2008-02-21 A | 100% |  | 2006-10-23 | 2007-12-01 | 290d? |  | finish no earlier than 2008-02-21 | S2 | 2792h | 2792h | IMS_CSC | 23.892 | Andy Bennett (Alcatel-Lucent) | andybennett@Alcatel-Lucent.com | Rel-8 | Maurice |  |
| 327 | 80 | Study on IMS utilizing multicast bearer services | 444d? | 2006-03-22 A | 2007-12-03 A | 100% |  | 2006-03-22 | 2007-12-03 | 444d? |  | finish no earlier than 2007-12-03 | S2 | 3552h | 3552h | FS-MLTICAST-IMS | 23.847 | Fiona Zhu (Siemens AG) |  | Rel-8 | Maurice |  |
| 328 | 81 | Study on Paging Permission with Access Control | 256d? | 2006-09-28 A | 2007-09-20 A | 100% |  | 2006-09-28 | 2007-09-20 | 256d? |  | finish no earlier than 2007-09-20 | S1 | 2048h | 2048h | PPAC | 22.908 | Katsuhiro Noguchi (NTT DoCoMo Inc.) | noguchi@nttdocomo.co.jp | Rel-8 | Alain |  |
| 329 | 82 | Study on Non 3GPP access NSP | 249d? | 2006-12-06 A | 2007-11-19 A | 100% |  | 2006-12-06 | 2007-11-19 | 249d? |  | finish no earlier than 2007-11-19 | S1 | 1992h | 1992h | N3GtoNSP | 22.812 | Chris Friel (O2) | chris.friel@o2.com | Rel-8 | Alain |  |
| 330 | 83 | Study on Value Added Services for Short Message Service | 263d? | 2006-12-06 A | 2007-12-07 A | 100% |  | 2006-12-06 | 2007-12-07 | 263d? |  | finish no earlier than 2007-12-07 | S1 | 2104h | 2104h | FSVAS4SMS | 22.942 | Wu Bin (China Mobile Communications Corporation) | wubin@chinamobile.com | Rel-8 | Alain |  |
| 331 | 84 | Study on Service continuity between mobile and WLAN networks | 262d? | 2006-12-06 A | 2007-12-06 | 90% | 26.2d? | 2006-12-06 | 2007-12-06 | 262d? | 390d | finish no earlier than 2007-12-06 | S1 | 2096h | 1886.4h | SMLSWLAN | 22.937 | Mike Meyerstein (BT) | mike.meyerstein@bt.com | Rel-8 | Alain |  |
| 332 | 85 | Study of Mobility between 3GPP-WLAN Interworking and 3GPP Systems | 129d? | 2007-03-20 A | 2007-09-14 A | 100% |  | 2007-03-20 | 2007-09-14 | 129d? |  | start no earlier than 2007-03-20 | S2 | 1032h | 1032h | SM3GWLAN | 23.837 | Orange | orange | Rel-8 | Maurice |  |
| 333 | 86 | **OAM&P Rel-8 Studies** | 742d? | 2006-05-10 A | 2009-03-12 | 65% | 260.82d? | 2006-05-10 | 2008-09-11 | 612d? | 60d |  | S5 | 24097.6h | 13405.6h | OAM8-Studies |  |  |  | Rel-8 | Adrian |  |
| 334 | 86.1 | Study of Element Operations Systems Function (EOSF) definition | 396d? | 2007-06-07 A | 2008-12-11 | 70% | 118.8d? | 2007-06-07 | 2008-09-11 | 331d? | 125d | finish no earlier than 2008-12-11 | S5 | 3168h | 2217.6h |  | TR 32.819 | China Mobile |  | Rel-8 |  | SP-32 |
| 335 | 86.2 | Study on SA5 MTOSI XML Harmonization | 351d? | 2006-05-10 A | 2007-09-12 A | 100% |  | 2006-05-10 | 2007-09-12 | 351d? |  | finish no earlier than 2007-12-14 | S5 | 2808h | 2808h |  | TR 32.818 | Nortel |  | Rel-8 |  | SP-32 |
| 336 | 86.3 | Study of Common Profile Storage (CPS) Framework of User Data for network services and management | 244d? | 2006-07-03 A | 2007-06-07 A | 100% |  | 2006-07-03 | 2007-06-07 | 244d? |  | finish no earlier than 2007-06-07 | S5 | 1952h | 1952h |  | TR 32.808 | T-Mobile |  | Rel-8 |  |  |
| 337 | 86.4 | Study of Management for LTE and SAE | 526d? | 2006-12-07 A | 2008-12-11 | 85% | 78.9d? | 2006-12-07 | 2008-06-12 | 396d? | 125d | finish no earlier than 2008-12-11 | S5 | 4208h | 3576.8h |  | TR 32.816 | Ericsson |  | Rel-8 |  |  |
| 338 | 86.5 | Study of System Maintenance over Itf-N | 396d? | 2007-06-07 A | 2008-12-11 | 50% | 198d? | 2007-06-07 | 2008-06-12 | 266d? | 125d | finish no earlier than 2008-12-11 | S5 | 3168h | 1584h |  | TR 32.822 | ZTE |  | Rel-8 |  |  |
| 339 | 86.6 | Study of Self-Organizing Networks (SON) related OAM interfaces for Home NodeB | 396d? | 2007-06-07 A | 2008-12-11 | 40% | 237.6d? | 2007-06-07 | 2008-06-12 | 266d? | 125d | finish no earlier than 2008-12-11 | S5 | 3168h | 1267.2h |  | TR 32.821 | Huawei |  | Rel-8 |  |  |
| 340 | 86.7 | Study on Self-healing of Self-Organizing Networks (SON) | 275d? | 2008-02-22 | 2009-03-12 |  |  | 2007-06-07 | 2008-06-12 | 266d? | 60d | finish no earlier than 2009-03-12 | S5 | 2200h |  |  | TR 32.8xy | ZTE |  | Rel-8 |  |  |
| 341 | 87 | Study on AS-MRFC media server control protocol | 583d? | 2006-03-22 A | 2008-06-13 | 90% | 58.3d? | 2006-03-22 | 2008-03-15 | 518d? | 254d | finish no earlier than 2008-06-13 | C1 | 4664h | 4197.6h | MRFC | 24.880 | Mark Syrett (Hewlett-Packard) | mark.syrett@hp.com | Rel-8 | Andrijana |  |
| 342 | 88 | Study on Restoration Procedures | 310d? | 2007-03-26 A | 2008-05-30 | 79% | 65.1d? | 2007-03-26 | 2008-03-14 | 255d? | 264d | finish no earlier than 2008-05-30 | C4 | 2480h | 1959.2h | FSIMS8_RP | TR 23.820 | German Blanco (Ericsson) | german.blanco@ericsson.com | Rel-8 | Kimmo |  |
| 343 | 89 | Study on 3G Home NodeB/eNodeB | 274d? | 2007-03-05 A | 2008-03-20 | 65% | 95.9d? | 2007-03-05 | 2007-12-21 | 210d? | 315d | finish no earlier than 2008-03-20 | R4 | 2192h | 1424.8h | RANFS-HNBeNB |  | Howard Thomas (Motorola) |  | Rel-8 | Claude |  |
| 344 | 90 | Study on Multimedia Session Continuity | 253d? | 2007-04-26 A | 2008-04-14 | 90% | 25.3d? | 2007-04-26 | 2008-03-14 | 232d? | 298d | finish no earlier than 2008-04-14 | S2 | 2024h | 1821.6h | MMSC_FS | 23.893 | Jaeseung Song (LG Electronics) |  | Rel-8 | Maurice |  |
| 345 | 91 | Study on CS Domain Services over evolved PS access | 359d? | 2007-04-25 A | 2008-09-08 | 70% | 107.7d? | 2007-04-25 | 2008-03-14 | 233d? | 193d | finish no earlier than 2008-09-08 | S2 | 2872h | 2010.4h | FS_CSoPS | 23.879 | Sabine Demel (T-Mobile International) | Sabine(dot)Demel(at)T-Mobile(dot)at | Rel-8 | Maurice |  |
| 346 | 92 | Study on Transferring of emergency call data – in-band modem solution | 466d? | 2006-12-07 A | 2008-09-18 A | 100% |  | 2006-12-07 | 2008-09-18 | 466d? |  | finish no earlier than 2008-09-18 | S4 | 3728h | 3728h | eCALLIBMS | 26.967 | Leon Hong, Airbiquity | lhong@airbiquity.com | Rel-8 | Paolo |  |
| 347 | 93 | Study on Improved network controlled mobility between LTE and 3GPP2/mobile WiMAX radio technologies | 131d? | 2007-06-04 A | 2007-12-03 A | 100% |  | 2007-06-04 | 2007-12-03 | 131d? |  | finish no earlier than 2007-12-03 | R2 | 1048h | 1048h | RANFS-LTEmob | TR 36.938 | Hao Bi, Motorola | hao.bi@Motorola.com | Rel-8 | Claude |  |
| 348 | 94 | Study on IMS Application Server Service Data Descriptions for AS interoperability | 261d? | 2007-09-14 A | 2008-09-12 | 40% | 156.6d? | 2007-09-14 | 2008-03-14 | 131d? | 189d | finish no earlier than 2008-09-12 | C4 | 2088h | 835.2h | FSIMS8_ASIO | TR 29.864 | Nigel Berry (Alcatel-Lucent | nhberry@ALCATEL-LUCENT.COM | Rel-8 | Kimmo |  |

Notes:
- 324: 22.892 planed to be withdrawn at SA#40
- 325: 22.892 planed to be withdrawn at SA#40
- 326: Name changed from "Study on Centralised IMS Service Control"
- 331: Name changed from "Study on Requirements for seamless roaming and service continuity between mobile and WLAN networks"
- 333: Created to encompass the Rel7 Work Tasks shifted to Rel8
- 340: SA#39 WID Approval
- 344: SID approved at SP-36. Updated as SP-37. For information to SA#38
- 345: SID approved at SP-36. TR for information to SA#38
- 346: Moved from Rel7

| ID | WBS | Task | Type | Duration | Start | Finish | Complete | Remaining | Baseline start | Baseline finish | Baseline duration | Total slack | Constraint | Resources | Work | Actual work | Text1 | Text3 | Text5 | Text6 | Text8 | Text7 |
| --- | --- | --- | --- | --- | --- | --- | --- | --- | --- | --- | --- | --- | --- | --- | --- | --- | --- | --- | --- | --- | --- | --- |
| 349 | 95 | **Study on CAT solution for voice and video call in CS domain** |  | 261d? | 2007-09-14 A | 2008-09-12 | 21% | 206.76d? | 2007-09-14 | 2008-04-11 | 150.65d? | 189d |  | C4 | 6106.8h | 1269.13h | FSCusAlert-St3 | TR 29.882 | zhanghao@chinamobile.com | Rel-8 | Kimmo |  |
| 350 | 95.1 | Study on CAT solution for voice and video call in CS domain |  | 261d? | 2007-09-14 A | 2008-09-12 | 40% | 156.6d? | 2007-09-14 | 2008-03-14 | 131d? | 189d | finish no earlier than 2008-09-12 | C4 | 2088h | 835.2h | FSCusAlert-St3 | TR 29.882 | zhanghao@chinamobile.com | Rel-8 | Kimmo |  |
| 351 | 95.2 | CT3 Review of CT4's Study on CAT |  | 241.35d? | 2007-09-14 A | 2008-09-12 |  | 241.35d? | 2007-09-14 | 2008-04-11 | 131d? | 189d | finish no earlier than 2008-09-12 | C3 | 1930.8h |  | FSCusAlert-St3_rev | TR 29.882 | zhanghao@chinamobile.com | Rel-8 | Kimmo |  |
| 352 | 96 | SI on Architecture of Customized Alerting Tone |  | 200d? | 2007-12-04 A | 2008-09-08 | 10% | 180d? |  |  |  | 193d | finish no earlier than 2008-09-08 | S2 | 1600h | 160h | FSCusAlert-St2 |  | wangjing@chinamobilecom | Rel-9 | Maurice |  |
| 353 | 97 | **Study on 3GPP System Architecture Evolution** |  | 802d? | 2004-12-03 A | 2007-12-31 A | 100% |  | 2004-12-03 | 2007-12-31 | 802d? |  |  | S2 | 12392h | 12392h | SAE |  |  | Rel-8 | Dioniso | TSG |
| 354 | 97.1 | Stage 2 Interim conclusion for RAN Work to start |  | 211d? | 2004-12-03 A | 2005-09-23 A | 100% |  | 2004-12-03 | 2005-09-23 | 211d? |  | finish no earlier than 2005-09-23 | S2 | 1688h | 1688h |  | 23.882 |  | Rel-8 |  |  |
| 355 | 97.2 | Stage 2 study on 3GPP architectural development |  | 450d? | 2006-01-09 A | 2007-09-28 A | 100% |  | 2006-01-09 | 2007-09-28 | 450d? |  | finish no earlier than 2007-09-28 | S2 | 3600h | 3600h |  | 23.882 |  | Rel-8 | Maurice |  |
| 356 | 97.3 | Security study for Inter-access mobility between non 3GPP and 3GPP system |  | 86d? | 2007-09-03 A | 2007-12-31 A | 100% |  | 2007-09-03 | 2007-12-31 | 86d? |  | start no earlier than 2007-09-01 | S3 | 688h | 688h | SAE-Sec | 23.882, 33.821, 33.922 | dajiang.zhang@NOKIA.COM | Rel-8 | Dioniso |  |
| 357 | 98 | Study on Scope of future HSPA Evolution for 1.28Mcps TDD |  | 195d? | 2007-09-14 A | 2008-06-12 | 40% | 117d? | 2007-09-14 | 2008-05-15 | 175d? | 255d | finish no earlier than 2008-06-12 | R1 | 1560h | 624h | RANFS-LCRTDDHSPAEvo | TR 25.9xx |  | Rel-8 | Claude |  |
| 358 | 99 | Study on Synchronised E-DCH for UTRA FDD |  | 131d? | 2007-09-14 A | 2008-03-14 | 20% | 104.8d? | 2007-09-14 | 2008-03-14 | 131d? | 319d | finish no earlier than 2008-03-14 | R1 | 1048h | 209.6h | RANFS-UplinkSync | TR 25.9xx | Karri.Ranta-aho@nsn.com | Rel-8 | Claude |  |
| 359 | 100 | Study on Extended Support of IMS Emergency Calls |  | 320d? | 2007-09-24 A | 2008-12-12 | 15% | 272d? | 2007-09-24 | 2008-03-14 | 125d? | 124d | finish no earlier than 2008-12-12 | S2 | 2560h | 384h | FSExIMSEm | 23.868 |  | Rel-8 | Maurice |  |
| 360 | 101 | Study on System enhancements for the use of IMS services in local breakout |  | 315d? | 2007-10-01 A | 2008-12-12 | 20% | 252d? | 2007-10-01 | 2008-05-23 | 170d? | 124d | finish no earlier than 2008-12-12 | S2 | 2520h | 504h | FSIMS_LBO | 22.8xx |  | Rel-8 | Maurice |  |
| 361 | 102 | Study on Services Alignment and Migration |  | 256d? | 2006-12-06 A | 2007-11-28 A | 100% |  | 2006-12-06 | 2007-11-28 | 256d? |  | finish no earlier than 2007-09-20 | S1 | 2048h | 2048h | FSServAl | 22.983 | fenglingjuan@chinamobile.com | Rel-8 | Alain |  |
| 362 | 103 | Study on A-interface over IP |  | 126d? | 2007-08-31 A | 2008-02-22 A | 100% |  | 2007-08-31 | 2008-02-22 | 126d? |  | finish no earlier than 2008-02-22 | GP | 1008h | 1008h | AINTIP | TR 43.903 | paul.schliwa-bertling@ericsson.com | Rel-8 | Paolo, Gert |  |
| 363 | 104 | Study on Multi-User Reusing-One-Slot |  | 131d? | 2007-11-16 A | 2008-05-16 | 20% | 104.8d? | 2007-11-16 | 2008-05-16 | 131d? | 274d | finish no earlier than 2008-05-16 | GP | 1048h | 209.6h | MUROS | TR | juergen.hofmann@nsn.com | Rel-8 | Paolo |  |
| 364 | 105 | Study on InterWorking Function between MAP based and Diameter based interfaces |  | 211d? | 2007-11-30 A | 2008-09-19 | 5% | 200.45d? | 2007-11-30 | 2008-09-19 | 211d? | 184d | finish no earlier than 2008-09-19 | C4 | 1688h | 84.4h | FSMAP2Diam | 29.8xy | liming49985@HUAWEI.COM | Rel-8 | Kimmo |  |
| 365 | 106 | Evaluation of LCS Control Plane Solution for EPS |  | 310d? | 2008-01-14 A | 2009-03-20 | 20% | 248d? | 2007-09-03 | 2007-12-14 | 75d? | 54d | finish no earlier than 2009-03-20 | S2 | 2480h | 496h | FSLCS_EPS | 23.8xx |  | Rel-9 | Maurice |  |
| 366 | 107 | Study on Evaluation of the inclusion of Path Loss Based Technology in the UTRAN |  | 195d? | 2007-12-17 | 2008-09-12 |  |  |  |  |  | 189d | start no earlier than 2007-12-17 | R4 | 1560h |  | RANFS-Pathloss | TR 25.9xx |  | Rel-8 | Claude |  |
| 367 | 108 | Study on HS-PDSCH serving cell change enhancements |  | 129d? | 2007-12-17 | 2008-06-12 |  |  |  |  |  | 255d | finish no earlier than 2008-06-12 | R4 | 1032h |  | RANFS-HSPDSCH | TR 25.9xx |  | Rel-8 | Claude |  |
| 368 | 109 | Study on Optimized Transmit Pulse Shape for Downlink EGPRS2-B |  | 206d? | 2007-11-16 A | 2008-08-29 | 10% | 185.4d? |  |  |  | 199d | start no earlier than 2007-11-16 | G1 | 1648h | 164.8h | WIDER | 45.9xx | jdwyer@RIM.COM and eddie.riddington@nsn.com | Rel-8 | Paolo |  |
| 369 | 110 | Deleted - equals 340035 -FS on Service continuity between mobile and WLAN networks |  | 75d? | 2007-09-03 | 2007-12-14 |  |  | 2007-09-03 | 2007-12-14 | 75d? | 384d | finish no earlier than 2007-12-14 | S1 | 600h |  | FSSCMobToW | 22.937 | mike.meyerstein@bt.com | Rel-8 |  |  |
| 370 | 111 | Deleted - Study on GAN Enhancements |  | 206d? | 2006-11-17 A | 2007-08-31 A | 100% |  | 2006-11-17 | 2007-08-31 | 206d? |  | start no earlier than 2006-11-17 | GP | 1648h | 1648h | EGAN | 43.902 | janne.linkola@t-mobile.com | Rel-7 | Paolo |  |
| 371 | 112 | **Abandoned - Study on All-IP Network** |  | 448d? | 2004-06-28 A | 2006-03-15 A | 100% |  | 2004-06-28 | 2006-03-15 | 448d? |  |  | S1 | 8672h | 8672h | AIPN | 22.978 | c.masyu@nttdocomo.co.jp | Rel-8 | Alain | TSG |
| 372 | 112.1 | Abandoned - All-IP Network Feasibility Study |  | 188d? | 2004-06-28 A | 2005-03-16 A | 100% |  | 2004-06-28 | 2005-03-16 | 188d? |  | start no earlier than 2004-06-28 | S1 | 1504h | 1504h | AIPFS | 22.978 | c.masyu@nttdocomo.co.jp | Rel-8 | Alain | TSG |
| 373 | 112.2 | Abandoned - draft Stage 1 |  | 448d? | 2004-06-28 A | 2006-03-15 A | 100% |  | 2004-06-28 | 2006-03-15 | 448d? |  | finish no earlier than 2006-03-15 | S1 | 3584h | 3584h | AIPN | 22.258 | c.masyu@nttdocomo.co.jp | Rel-8 | Alain | TSG |
| 374 | 113 | Release 9 Features | milestone | 0d? | 2007-09-19 | 2007-09-19 |  |  | 2007-09-19 | 2007-09-19 | 0d? | 447d | finish no earlier than 2007-09-19 | CT;RAN;SA |  |  |  |  |  | Rel-9 |  |  |
| 375 | 114 | End-User Identity |  | 75d? | 2007-09-03 A | 2007-12-14 | 5% | 71.25d? | 2007-09-03 | 2007-12-14 | 75d? | 384d | finish no earlier than 2007-12-14 | S1 | 600h | 30h | EUI | 22.101 | Joerg.Swetina@Siemens.com | Rel-9 |  |  |

Notes:
- 349: Text4: Zhang Hao (China Mobile)
- 350: Text4: Zhang Hao (China Mobile)
- 351: Text4: Zhang Hao (China Mobile)
- 352: Text4: Wang Jing, China Mobile
- 353: Moved from Rel-7
- 354: Moved from Rel-7
- 355: Moved from Rel-7 / Text4: Chris Pudney
- 356: Moved from Rel-7 / Text4: Dajiang Zhang (Nokia)
- 357: Text4: Xu Fei, RITT
- 358: Text4: Karri Ranta-aho, Nokia Siemens Networks
- 359: Approved SP-37 / Text4: Stephen Edge (Qualcomm)
- 360: SID approved SA#37 / Text4: Mario Madella, Telecom Italia
- 361: Created at SA1#38 to dissociate TR from TS / Text4: Feng Lingjuan (China Mobile)
- 362: Completed / Text4: Wang Shuaiyu, China Mobile and Paul Schliwa-Bertling, Ericsson
- 363: Text4: Juergen Hofmann (Nokia Siemens Networks)
- 364: Text4: Li Ming
- 365: SID approved SA#38 / Text4: Robert Gross (SiRF Technology)
- 366: Text4: Norman Shaw, Polaris Wireless, Inc.
- 367: Text4: Josef Blanz, Qualcomm Europe
- 368: Text4: Johanna Dwyer, ResearcH In Motion and Eddie Riddington, Nokia Siemens Networks
- 369: Text4: Mike Meyerstein, BT
- 370: Completed for Rel7 / Text4: Janne Linkola (T-Mobile)
- 371: Text4: Chris Sachno (NTT DoCoMo)
- 372: Text4: Chris Sachno (NTT DoCoMo)
- 373: 22.258 withdrawm, superseded by 22.278 (UID 320022) / Text4: Chris Sachno (NTT DoCoMo)
- 375: Moved to Rel-9 at SA1#38 / Text4: Joerg Swetina (Nokia Siemens Network)

| ID | WBS | Task | Type | Duration | Start | Finish | Complete | Remaining | Baseline start | Baseline finish | Baseline duration | Total slack | Constraint | Resources | Work | Actual work | Text1 | Text6 | Text3 | Text4 | Text8 | Text5 |
| --- | --- | --- | --- | --- | --- | --- | --- | --- | --- | --- | --- | --- | --- | --- | --- | --- | --- | --- | --- | --- | --- | --- |
| 376 | 115 | **Public Warning System** |  | 71d? | 2007-12-06 | 2008-03-13 |  |  |  |  |  | 320d |  | S1 | 1136h |  | PWS | Rel-9 |  |  |  |  |
| 377 | 115.1 | Stage 1 for PWS |  | 71d? | 2007-12-06 | 2008-03-13 |  |  |  |  |  | 320d | start no earlier than 2007-12-06 | S1 | 568h |  | PWS-S1 | Rel-9 |  |  |  |  |
| 378 | 116 | Support of WiMAX - LTE Mobility |  | 327d? | 2007-12-17 | 2009-03-17 |  |  |  |  |  | 57d | finish no earlier than 2009-03-17 | R2 | 2616h |  | LTEWiMAXMob | Rel-9 | 36.306, 36.331, 36.413, 36.300, 36.214, 36.133, 36.304 | Kyeongin Jeong, Samsung | Claude |  |
| 379 | 117 | Support of WiMAX - UMTS Mobility |  | 327d? | 2007-12-17 | 2009-03-17 |  |  |  |  |  | 57d | finish no earlier than 2009-03-17 | R2 | 2616h |  | UMTSWiMAXMob | Rel-9 | 25.306, 25.331, 25.413 | Vivek Gupta, Intel | Claude |  |
| 380 | 118 | Rel-9 Feasibility Studies | milestone | 0d | 2007-09-19 | 2007-09-19 |  |  | 2007-09-19 | 2007-09-19 | 0d | 447d | start no earlier than 2007-09-19 | CT;RAN;SA |  |  |  | Rel-9 |  |  |  |  |
| 381 | 119 | Study on Remote management of USIM application on M2M Equipment |  | 263d? | 2007-09-19 A | 2008-09-19 | 20% | 210.4d? | 2007-09-19 | 2008-09-19 | 263d? | 184d | finish no earlier than 2008-09-19 | S3 | 2104h | 420.8h | FSUM2M | Rel-9 | 33.8yz | Vesa Lehtovirta (Ericsson) |  | vesa.lehtovirta@ericsson.com |
| 382 | 120 | **Study on enhanced voice service requirements for the EPS** |  | 140d? | 2007-09-03 A | 2008-03-14 | 16% | 118.3d? | 2007-09-03 | 2008-03-14 | 140d? | 319d |  | S1 | 3360h | 520.8h | FSEV_EPS | Rel-9 | 22.813 | Tim Haysom, Orange |  | tim.haysom@orange-ftgroup.com |
| 383 | 120.1 | Use cases definition and service and system requirements |  | 140d? | 2007-09-03 A | 2008-03-14 | 31% | 96.6d? | 2007-09-03 | 2008-03-14 | 140d? | 319d | start no earlier than 2007-09-03 | S1 | 1120h | 347.2h | FSEV_EPS-S1 | Rel-9 |  | Tim Haysom, Orange |  | tim.haysom@orange-ftgroup.com |
| 384 | 120.2 | Codec specific part of FSEV_EPS |  | 140d? | 2007-09-03 | 2008-03-14 |  |  | 2007-09-03 | 2008-03-14 | 140d? | 319d | start no earlier than 2007-09-03 | S4 | 1120h |  | FSEV_EPS-S4 | Rel-9 |  | Tim Haysom, Orange |  | tim.haysom@orange-ftgroup.com |
| 385 | 121 | Study on support of a Public Warning System |  | 140d? | 2007-09-03 A | 2008-03-14 A | 100% |  | 2006-06-08 | 2008-01-31 | 431d? |  |  | S1 | 1120h | 1120h | FSPWS | Rel-9 | 22.968 | Mark Young (T-mobile) | Alain | mark.younge@t-mobile.com |
| 386 | 122 | SI on advanced requirements for IP interconnect |  | 78d? | 2007-12-04 | 2008-03-20 |  |  |  |  |  | 315d | finish no earlier than 2008-03-20 | S1 | 624h |  | IPXS | Rel-9 | 22.893 | Chris Friel (Telefonica O2 Europe) | Alain | chris.friel@O2.com |
| 387 | 123 | FS on UTRAN key management enhancements |  | 192d? | 2007-12-20 | 2008-09-12 |  |  |  |  |  | 189d | finish no earlier than 2008-09-12 | S3 | 1536h |  | FSUKM | Rel-9 |  | Karl Norrman, Ericsson |  |  |
| 388 | 124 | FS on Home (e)NobeB Security |  | 192d? | 2007-12-20 | 2008-09-12 |  |  |  |  |  | 189d | start no earlier than 2007-12-20 | S3 | 1536h |  | FSHNB | Rel-9 |  | Yanmei Yang, Huawei |  | yangyanmei@huawei.com |

Notes:
- 382: Moved to Rel9
- 383: Moved to Rel9
- 384: Moved to Rel9
- 385: Acronym changed from "PWS-SI" to "FSPWS"
